# Ekushey Bhaban - Superstructure

Schedule from MS Project, 2011-07-28 to 2012-11-18.
SSL

## Calendars

- Standard: Mon-Fri 08:00-12:00, 13:00-17:00; Sat-Sun off. Exceptions (off unless hours are given): 2011-07-18 to 2011-08-14 08:00-12:00, 13:00-17:00 (Working Days-5), 2011-08-15 (National Mounring Day), 2011-08-16 to 2011-08-27 08:00-12:00, 13:00-17:00 (Working Days-6), 2011-08-28 to 2011-09-02 (Eid-ul Fitre), 2011-09-03 to 2011-10-05 08:00-12:00, 13:00-17:00 (Working Days-7), 2011-10-06 (Durga Puja), 2011-10-07 to 2011-11-05 08:00-12:00, 13:00-17:00 (Working Days-8), 2011-11-06 to 2011-11-11 (Eid-ul Azha), 2011-11-12 to 2011-12-05 08:00-12:00, 13:00-17:00 (Working Days-9), 2011-12-06 (Ashura), 2011-12-07 to 2011-12-15 08:00-12:00, 13:00-17:00 (Working Days-10), 2011-12-16 (Victory Day), 2011-12-17 to 2011-12-24 08:00-12:00, 13:00-17:00 (Working Days-11), 2011-12-25 (X-mas Day), 2011-12-26 to 2012-02-05 08:00-12:00, 13:00-17:00 (Working Days-12), 2012-02-06 (Eid-e-miladunnabi), 2012-02-07 to 2012-02-20 08:00-12:00, 13:00-17:00 (Working Days-13), 2012-02-21 (Ekushey Fubuary), 2012-02-22 to 2012-03-16 08:00-12:00, 13:00-17:00 (Working days-14), 2012-03-17 (Bangobondhu's Birthdayday), 2012-03-18 to 2012-04-13 08:00-12:00, 13:00-17:00 (Working Days-15), 2012-04-14 (Bangla New Year), 2012-04-15 to 2012-04-30 08:00-12:00, 13:00-17:00 (Working Days-16), 2012-05-01 (May Day), 2012-05-02 to 2012-05-16 08:00-12:00, 13:00-17:00 (Working Days-17), 2012-05-17 (Boudha Purnima), 2012-05-18 to 2012-07-06 08:00-12:00, 13:00-17:00 (Working Days-18), 2012-07-07 (Shob-e-Barat), 2012-07-08 to 2012-08-14 08:00-12:00, 13:00-17:00 (Working Days-19), 2012-08-15 (National Mourning Day), 2012-08-16 08:00-12:00, 13:00-17:00 (Working Days-20), 2012-08-17 (Jumatul Bida), 2012-08-18 to 2012-08-19 08:00-12:00, 13:00-17:00 (Working Days-21), 2012-08-20 to 2012-08-24 (Eid-ul Fitre), 2012-08-25 to 2012-10-05 08:00-12:00, 13:00-17:00 (Working Days-22), 2012-10-06 (Durga Puga), 2012-10-07 to 2012-10-27 08:00-12:00, 13:00-17:00 (Working Days-23), 2012-10-28 to 2012-11-02 (Eid-ul-Adha), 2012-11-03 to 2012-11-26 08:00-12:00, 13:00-17:00 (Working Days-24).

## Schedule

| ID | WBS | Task | Duration | Start | Finish | Predecessors | Total slack | Free slack |
| --- | --- | --- | --- | --- | --- | --- | --- | --- |
| 1 | 1 | **Ekushey Bhaban** | 442d | 2011-07-28 | 2012-11-18 |  | 0d |  |
| 2 | 1.1 | **Superstructure** | 300d | 2011-07-28 | 2012-06-14 |  | 0d |  |
| 3 | 1.1.1 | **Ground Floor** | 20d | 2011-07-28 | 2011-08-17 |  | 0d |  |
| 4 | 1.1.1.1 | Layout Work | 1d | 2011-07-28 | 2011-07-28 |  | 0d |  |
| 5 | 1.1.1.2 | **Column (17 nos): Lift-1** | 4d | 2011-07-29 | 2011-08-01 |  | 1d |  |
| 6 | 1.1.1.2.1 | Re-bar | 1d | 2011-07-29 | 2011-07-29 | 4 | 1d | 0d |
| 7 | 1.1.1.2.2 | Formwork | 2d | 2011-07-30 | 2011-07-31 | 6 | 1d | 0d |
| 8 | 1.1.1.2.3 | Concrete | 1d | 2011-08-01 | 2011-08-01 | 7 | 1d | 0d |
| 9 | 1.1.1.3 | **Column (17 nos): Lift-2** | 4d | 2011-08-02 | 2011-08-05 |  | 1d |  |
| 10 | 1.1.1.3.1 | Re-bar | 1d | 2011-08-02 | 2011-08-02 | 8 | 1d | 0d |
| 11 | 1.1.1.3.2 | Formwork | 2d | 2011-08-03 | 2011-08-04 | 10 | 1d | 0d |
| 12 | 1.1.1.3.3 | Concrete | 1d | 2011-08-05 | 2011-08-05 | 11 | 1d |  |
| 13 | 1.1.1.4 | **Lift Core: Lift-1** | 5d | 2011-07-29 | 2011-08-02 |  | 0d |  |
| 14 | 1.1.1.4.1 | Re-bar | 2d | 2011-07-29 | 2011-07-30 | 4 | 0d |  |
| 15 | 1.1.1.4.2 | Formwork | 2d | 2011-07-31 | 2011-08-01 | 14 | 0d |  |
| 16 | 1.1.1.4.3 | Concrete | 1d | 2011-08-02 | 2011-08-02 | 15 | 0d |  |
| 17 | 1.1.1.5 | **Lift Core: Lift-2** | 4d | 2011-08-03 | 2011-08-06 |  | 0d |  |
| 18 | 1.1.1.5.1 | Re-bar | 1d | 2011-08-03 | 2011-08-03 | 16 | 0d |  |
| 19 | 1.1.1.5.2 | Formwork | 2d | 2011-08-04 | 2011-08-05 | 18 | 0d |  |
| 20 | 1.1.1.5.3 | Concrete | 1d | 2011-08-06 | 2011-08-06 | 19 | 0d |  |
| 21 | 1.1.1.6 | **Stair Case (2 nos)-Flight-1** | 8d | 2011-07-30 | 2011-08-06 |  | 431d |  |
| 22 | 1.1.1.6.1 | Formwork | 4d | 2011-07-30 | 2011-08-03 | 4, 23SF | 435d |  |
| 23 | 1.1.1.6.2 | Re-bar | 3d | 2011-08-03 | 2011-08-06 | 24SF | 432d | 0d |
| 24 | 1.1.1.6.3 | Concrete | 1d | 2011-08-06 | 2011-08-06 | 20FF | 427d | 0d |

| ID | WBS | Task | Duration | Start | Finish | Predecessors | Total slack | Free slack |
| --- | --- | --- | --- | --- | --- | --- | --- | --- |
| 25 | 1.1.1.7 | **Stair Case (2 nos)-Flight-2** | 8d | 2011-08-09 | 2011-08-17 |  | 421d |  |
| 26 | 1.1.1.7.1 | Formwork | 4d | 2011-08-09 | 2011-08-13 | 24, 27SF | 425d |  |
| 27 | 1.1.1.7.2 | Re-bar | 3d | 2011-08-13 | 2011-08-17 | 28SF | 422d | 0d |
| 28 | 1.1.1.7.3 | Concrete | 1d | 2011-08-17 | 2011-08-17 | 34FF | 421d | 0d |
| 29 | 1.1.1.8 | **Roof Slab** | 10d | 2011-08-07 | 2011-08-17 |  | 0d |  |
| 30 | 1.1.1.8.1 | Formwork | 5d | 2011-08-07 | 2011-08-11 | 12, 20 | 0d |  |
| 31 | 1.1.1.8.2 | Re-bar | 3d | 2011-08-12 | 2011-08-14 | 30 | 0d |  |
| 32 | 1.1.1.8.3 | MEP Work | 2d | 2011-08-14 | 2011-08-16 | 31FF+1d | 0d |  |
| 33 | 1.1.1.8.4 | Inspection | 1d | 2011-08-16 | 2011-08-16 | 32FF | 0d |  |
| 34 | 1.1.1.8.5 | Concrete | 1d | 2011-08-17 | 2011-08-17 | 33 | 0d |  |
| 35 | 1.1.2 | **1st Floor** | 20d | 2011-08-18 | 2011-09-12 |  | 0d |  |
| 36 | 1.1.2.1 | Layout Work | 1d | 2011-08-18 | 2011-08-18 | 34 | 0d |  |
| 37 | 1.1.2.2 | **Column (17 nos): Lift-1** | 4d | 2011-08-19 | 2011-08-22 |  | 1d |  |
| 38 | 1.1.2.2.1 | Re-bar | 1d | 2011-08-19 | 2011-08-19 | 36 | 1d | 0d |
| 39 | 1.1.2.2.2 | Formwork | 2d | 2011-08-20 | 2011-08-21 | 38 | 1d | 0d |
| 40 | 1.1.2.2.3 | Concrete | 1d | 2011-08-22 | 2011-08-22 | 39 | 1d | 0d |
| 41 | 1.1.2.3 | **Column (17 nos): Lift-2** | 4d | 2011-08-23 | 2011-08-26 |  | 1d |  |
| 42 | 1.1.2.3.1 | Re-bar | 1d | 2011-08-23 | 2011-08-23 | 40 | 1d | 0d |
| 43 | 1.1.2.3.2 | Formwork | 2d | 2011-08-24 | 2011-08-25 | 42 | 1d | 0d |
| 44 | 1.1.2.3.3 | Concrete | 1d | 2011-08-26 | 2011-08-26 | 43 | 1d |  |
| 45 | 1.1.2.4 | **Lift Core: Lift-1** | 5d | 2011-08-19 | 2011-08-23 |  | 0d |  |
| 46 | 1.1.2.4.1 | Re-bar | 2d | 2011-08-19 | 2011-08-20 | 36 | 0d |  |
| 47 | 1.1.2.4.2 | Formwork | 2d | 2011-08-21 | 2011-08-22 | 46 | 0d |  |
| 48 | 1.1.2.4.3 | Concrete | 1d | 2011-08-23 | 2011-08-23 | 47 | 0d |  |

| ID | WBS | Task | Duration | Start | Finish | Predecessors | Total slack | Free slack |
| --- | --- | --- | --- | --- | --- | --- | --- | --- |
| 49 | 1.1.2.5 | **Lift Core: Lift-2** | 4d | 2011-08-24 | 2011-08-27 |  | 0d |  |
| 50 | 1.1.2.5.1 | Re-bar | 1d | 2011-08-24 | 2011-08-24 | 48 | 0d |  |
| 51 | 1.1.2.5.2 | Formwork | 2d | 2011-08-25 | 2011-08-26 | 50 | 0d |  |
| 52 | 1.1.2.5.3 | Concrete | 1d | 2011-08-27 | 2011-08-27 | 51 | 0d |  |
| 53 | 1.1.2.6 | **Stair Case (2 nos)-Flight-1** | 8d | 2011-08-20 | 2011-08-27 |  | 411d |  |
| 54 | 1.1.2.6.1 | Formwork | 4d | 2011-08-20 | 2011-08-24 | 55SF, 36 | 415d |  |
| 55 | 1.1.2.6.2 | Re-bar | 3d | 2011-08-24 | 2011-08-27 | 56SF | 412d | 0d |
| 56 | 1.1.2.6.3 | Concrete | 1d | 2011-08-27 | 2011-08-27 | 52FF | 411d | 0d |
| 57 | 1.1.2.7 | **Stair Case (2 nos)-Flight-2** | 8d | 2011-09-05 | 2011-09-12 |  | 401d |  |
| 58 | 1.1.2.7.1 | Formwork | 4d | 2011-09-05 | 2011-09-09 | 59SF, 52 | 405d |  |
| 59 | 1.1.2.7.2 | Re-bar | 3d | 2011-09-09 | 2011-09-12 | 60SF | 402d | 0d |
| 60 | 1.1.2.7.3 | Concrete | 1d | 2011-09-12 | 2011-09-12 | 66FF | 401d | 0d |
| 61 | 1.1.2.8 | **Roof Slab** | 10d | 2011-09-03 | 2011-09-12 |  | 0d |  |
| 62 | 1.1.2.8.1 | Formwork | 5d | 2011-09-03 | 2011-09-07 | 44, 52 | 0d |  |
| 63 | 1.1.2.8.2 | Re-bar | 3d | 2011-09-08 | 2011-09-10 | 62 | 0d |  |
| 64 | 1.1.2.8.3 | MEP Work | 2d | 2011-09-10 | 2011-09-11 | 63FF+1d | 0d |  |
| 65 | 1.1.2.8.4 | Inspection | 1d | 2011-09-11 | 2011-09-11 | 64FF | 0d |  |
| 66 | 1.1.2.8.5 | Concrete | 1d | 2011-09-12 | 2011-09-12 | 65 | 0d |  |
| 67 | 1.1.3 | **2nd Floor** | 20d | 2011-09-13 | 2011-10-02 |  | 0d |  |
| 68 | 1.1.3.1 | Layout Work | 1d | 2011-09-13 | 2011-09-13 | 66 | 0d |  |
| 69 | 1.1.3.2 | **Column (17 nos): Lift-1** | 4d | 2011-09-14 | 2011-09-17 |  | 1d |  |
| 70 | 1.1.3.2.1 | Re-bar | 1d | 2011-09-14 | 2011-09-14 | 68 | 1d | 0d |
| 71 | 1.1.3.2.2 | Formwork | 2d | 2011-09-15 | 2011-09-16 | 70 | 1d | 0d |
| 72 | 1.1.3.2.3 | Concrete | 1d | 2011-09-17 | 2011-09-17 | 71 | 1d | 0d |

| ID | WBS | Task | Duration | Start | Finish | Predecessors | Total slack | Free slack |
| --- | --- | --- | --- | --- | --- | --- | --- | --- |
| 73 | 1.1.3.3 | **Column (17 nos): Lift-2** | 4d | 2011-09-18 | 2011-09-21 |  | 1d |  |
| 74 | 1.1.3.3.1 | Re-bar | 1d | 2011-09-18 | 2011-09-18 | 72 | 1d | 0d |
| 75 | 1.1.3.3.2 | Formwork | 2d | 2011-09-19 | 2011-09-20 | 74 | 1d | 0d |
| 76 | 1.1.3.3.3 | Concrete | 1d | 2011-09-21 | 2011-09-21 | 75 | 1d |  |
| 77 | 1.1.3.4 | **Lift Core: Lift-1** | 5d | 2011-09-14 | 2011-09-18 |  | 0d |  |
| 78 | 1.1.3.4.1 | Re-bar | 2d | 2011-09-14 | 2011-09-15 | 68 | 0d |  |
| 79 | 1.1.3.4.2 | Formwork | 2d | 2011-09-16 | 2011-09-17 | 78 | 0d |  |
| 80 | 1.1.3.4.3 | Concrete | 1d | 2011-09-18 | 2011-09-18 | 79 | 0d |  |
| 81 | 1.1.3.5 | **Lift Core: Lift-2** | 4d | 2011-09-19 | 2011-09-22 |  | 0d |  |
| 82 | 1.1.3.5.1 | Re-bar | 1d | 2011-09-19 | 2011-09-19 | 80 | 0d |  |
| 83 | 1.1.3.5.2 | Formwork | 2d | 2011-09-20 | 2011-09-21 | 82 | 0d |  |
| 84 | 1.1.3.5.3 | Concrete | 1d | 2011-09-22 | 2011-09-22 | 83 | 0d |  |
| 85 | 1.1.3.6 | **Stair Case (2 nos)-Flight-1** | 8d | 2011-09-15 | 2011-09-22 |  | 391d |  |
| 86 | 1.1.3.6.1 | Formwork | 4d | 2011-09-15 | 2011-09-19 | 87SF, 68 | 395d |  |
| 87 | 1.1.3.6.2 | Re-bar | 3d | 2011-09-19 | 2011-09-22 | 88SF | 392d | 0d |
| 88 | 1.1.3.6.3 | Concrete | 1d | 2011-09-22 | 2011-09-22 | 84FF | 387d | 0d |
| 89 | 1.1.3.7 | **Stair Case (2 nos)-Flight-2** | 8d | 2011-09-25 | 2011-10-02 |  | 381d |  |
| 90 | 1.1.3.7.1 | Formwork | 4d | 2011-09-25 | 2011-09-29 | 91SF, 88 | 385d |  |
| 91 | 1.1.3.7.2 | Re-bar | 3d | 2011-09-29 | 2011-10-02 | 92SF | 382d | 0d |
| 92 | 1.1.3.7.3 | Concrete | 1d | 2011-10-02 | 2011-10-02 | 98FF | 381d | 0d |
| 93 | 1.1.3.8 | **Roof Slab** | 10d | 2011-09-23 | 2011-10-02 |  | 0d |  |
| 94 | 1.1.3.8.1 | Formwork | 5d | 2011-09-23 | 2011-09-27 | 76, 34FS+28d, 84 | 0d |  |
| 95 | 1.1.3.8.2 | Re-bar | 3d | 2011-09-28 | 2011-09-30 | 94 | 0d |  |
| 96 | 1.1.3.8.3 | MEP Work | 2d | 2011-09-30 | 2011-10-01 | 95FF+1d | 0d |  |
| 97 | 1.1.3.8.4 | Inspection | 1d | 2011-10-01 | 2011-10-01 | 96FF | 0d |  |
| 98 | 1.1.3.8.5 | Concrete | 1d | 2011-10-02 | 2011-10-02 | 97 | 0d |  |

| ID | WBS | Task | Duration | Start | Finish | Predecessors | Total slack | Free slack |
| --- | --- | --- | --- | --- | --- | --- | --- | --- |
| 99 | 1.1.4 | **3rd Floor** | 20d | 2011-10-03 | 2011-10-23 |  | 0d |  |
| 100 | 1.1.4.1 | Layout Work | 1d | 2011-10-03 | 2011-10-03 | 98 | 0d |  |
| 101 | 1.1.4.2 | **Column (17 nos): Lift-1** | 4d | 2011-10-04 | 2011-10-08 |  | 1d |  |
| 102 | 1.1.4.2.1 | Re-bar | 1d | 2011-10-04 | 2011-10-04 | 100 | 1d | 0d |
| 103 | 1.1.4.2.2 | Formwork | 2d | 2011-10-05 | 2011-10-07 | 102 | 1d | 0d |
| 104 | 1.1.4.2.3 | Concrete | 1d | 2011-10-08 | 2011-10-08 | 103 | 1d | 0d |
| 105 | 1.1.4.3 | **Column (17 nos): Lift-2** | 4d | 2011-10-09 | 2011-10-12 |  | 1d |  |
| 106 | 1.1.4.3.1 | Re-bar | 1d | 2011-10-09 | 2011-10-09 | 104 | 1d | 0d |
| 107 | 1.1.4.3.2 | Formwork | 2d | 2011-10-10 | 2011-10-11 | 106 | 1d | 0d |
| 108 | 1.1.4.3.3 | Concrete | 1d | 2011-10-12 | 2011-10-12 | 107 | 1d |  |
| 109 | 1.1.4.4 | **Lift Core: Lift-1** | 5d | 2011-10-04 | 2011-10-09 |  | 0d |  |
| 110 | 1.1.4.4.1 | Re-bar | 2d | 2011-10-04 | 2011-10-05 | 100 | 0d |  |
| 111 | 1.1.4.4.2 | Formwork | 2d | 2011-10-07 | 2011-10-08 | 110 | 0d |  |
| 112 | 1.1.4.4.3 | Concrete | 1d | 2011-10-09 | 2011-10-09 | 111 | 0d |  |
| 113 | 1.1.4.5 | **Lift Core: Lift-2** | 4d | 2011-10-10 | 2011-10-13 |  | 0d |  |
| 114 | 1.1.4.5.1 | Re-bar | 1d | 2011-10-10 | 2011-10-10 | 112 | 0d |  |
| 115 | 1.1.4.5.2 | Formwork | 2d | 2011-10-11 | 2011-10-12 | 114 | 0d |  |
| 116 | 1.1.4.5.3 | Concrete | 1d | 2011-10-13 | 2011-10-13 | 115 | 0d |  |
| 117 | 1.1.4.6 | **Stair Case (2 nos)-Flight-1** | 8d | 2011-10-05 | 2011-10-13 |  | 371d |  |
| 118 | 1.1.4.6.1 | Formwork | 4d | 2011-10-05 | 2011-10-10 | 119SF, 100 | 375d |  |
| 119 | 1.1.4.6.2 | Re-bar | 3d | 2011-10-10 | 2011-10-13 | 120SF | 372d | 0d |
| 120 | 1.1.4.6.3 | Concrete | 1d | 2011-10-13 | 2011-10-13 | 116FF | 367d | 0d |
| 121 | 1.1.4.7 | **Stair Case (2 nos)-Flight-2** | 8d | 2011-10-16 | 2011-10-23 |  | 361d |  |
| 122 | 1.1.4.7.1 | Formwork | 4d | 2011-10-16 | 2011-10-20 | 123SF, 120 | 365d |  |
| 123 | 1.1.4.7.2 | Re-bar | 3d | 2011-10-20 | 2011-10-23 | 124SF | 362d | 0d |
| 124 | 1.1.4.7.3 | Concrete | 1d | 2011-10-23 | 2011-10-23 | 130FF | 361d | 0d |

| ID | WBS | Task | Duration | Start | Finish | Predecessors | Total slack | Free slack |
| --- | --- | --- | --- | --- | --- | --- | --- | --- |
| 125 | 1.1.4.8 | **Roof Slab** | 10d | 2011-10-14 | 2011-10-23 |  | 0d |  |
| 126 | 1.1.4.8.1 | Formwork | 5d | 2011-10-14 | 2011-10-18 | 108, 66FS+28d, 116 | 0d |  |
| 127 | 1.1.4.8.2 | Re-bar | 3d | 2011-10-19 | 2011-10-21 | 126 | 0d |  |
| 128 | 1.1.4.8.3 | MEP Work | 2d | 2011-10-21 | 2011-10-22 | 127FF+1d | 0d |  |
| 129 | 1.1.4.8.4 | Inspection | 1d | 2011-10-22 | 2011-10-22 | 128FF | 0d |  |
| 130 | 1.1.4.8.5 | Concrete | 1d | 2011-10-23 | 2011-10-23 | 129 | 0d |  |
| 131 | 1.1.5 | **4th Floor** | 20d | 2011-10-24 | 2011-11-18 |  | 0d |  |
| 132 | 1.1.5.1 | Layout Work | 1d | 2011-10-24 | 2011-10-24 | 130 | 0d |  |
| 133 | 1.1.5.2 | **Column (17 nos): Lift-1** | 4d | 2011-10-25 | 2011-10-28 |  | 1d |  |
| 134 | 1.1.5.2.1 | Re-bar | 1d | 2011-10-25 | 2011-10-25 | 132 | 1d | 0d |
| 135 | 1.1.5.2.2 | Formwork | 2d | 2011-10-26 | 2011-10-27 | 134 | 1d | 0d |
| 136 | 1.1.5.2.3 | Concrete | 1d | 2011-10-28 | 2011-10-28 | 135 | 1d | 0d |
| 137 | 1.1.5.3 | **Column (17 nos): Lift-2** | 4d | 2011-10-29 | 2011-11-01 |  | 1d |  |
| 138 | 1.1.5.3.1 | Re-bar | 1d | 2011-10-29 | 2011-10-29 | 136 | 1d | 0d |
| 139 | 1.1.5.3.2 | Formwork | 2d | 2011-10-30 | 2011-10-31 | 138 | 1d | 0d |
| 140 | 1.1.5.3.3 | Concrete | 1d | 2011-11-01 | 2011-11-01 | 139 | 1d |  |
| 141 | 1.1.5.4 | **Lift Core: Lift-1** | 5d | 2011-10-25 | 2011-10-29 |  | 0d |  |
| 142 | 1.1.5.4.1 | Re-bar | 2d | 2011-10-25 | 2011-10-26 | 132 | 0d |  |
| 143 | 1.1.5.4.2 | Formwork | 2d | 2011-10-27 | 2011-10-28 | 142 | 0d |  |
| 144 | 1.1.5.4.3 | Concrete | 1d | 2011-10-29 | 2011-10-29 | 143 | 0d |  |
| 145 | 1.1.5.5 | **Lift Core: Lift-2** | 4d | 2011-10-30 | 2011-11-02 |  | 0d |  |
| 146 | 1.1.5.5.1 | Re-bar | 1d | 2011-10-30 | 2011-10-30 | 144 | 0d |  |
| 147 | 1.1.5.5.2 | Formwork | 2d | 2011-10-31 | 2011-11-01 | 146 | 0d |  |
| 148 | 1.1.5.5.3 | Concrete | 1d | 2011-11-02 | 2011-11-02 | 147 | 0d |  |

| ID | WBS | Task | Duration | Start | Finish | Predecessors | Total slack | Free slack |
| --- | --- | --- | --- | --- | --- | --- | --- | --- |
| 149 | 1.1.5.6 | **Stair Case (2 nos)-Flight-1** | 8d | 2011-10-26 | 2011-11-02 |  | 351d |  |
| 150 | 1.1.5.6.1 | Formwork | 4d | 2011-10-26 | 2011-10-30 | 151SF, 132 | 355d |  |
| 151 | 1.1.5.6.2 | Re-bar | 3d | 2011-10-30 | 2011-11-02 | 152SF | 352d | 0d |
| 152 | 1.1.5.6.3 | Concrete | 1d | 2011-11-02 | 2011-11-02 | 148FF | 347d | 0d |
| 153 | 1.1.5.7 | **Stair Case (2 nos)-Flight-2** | 8d | 2011-11-05 | 2011-11-18 |  | 341d |  |
| 154 | 1.1.5.7.1 | Formwork | 4d | 2011-11-05 | 2011-11-15 | 155SF, 152 | 345d |  |
| 155 | 1.1.5.7.2 | Re-bar | 3d | 2011-11-15 | 2011-11-18 | 156SF | 342d | 0d |
| 156 | 1.1.5.7.3 | Concrete | 1d | 2011-11-18 | 2011-11-18 | 162FF | 341d | 0d |
| 157 | 1.1.5.8 | **Roof Slab** | 10d | 2011-11-03 | 2011-11-18 |  | 0d |  |
| 158 | 1.1.5.8.1 | Formwork | 5d | 2011-11-03 | 2011-11-13 | 140, 98FS+28d, 148 | 0d |  |
| 159 | 1.1.5.8.2 | Re-bar | 3d | 2011-11-14 | 2011-11-16 | 158 | 0d |  |
| 160 | 1.1.5.8.3 | MEP Work | 2d | 2011-11-16 | 2011-11-17 | 159FF+1d | 0d |  |
| 161 | 1.1.5.8.4 | Inspection | 1d | 2011-11-17 | 2011-11-17 | 160FF | 0d |  |
| 162 | 1.1.5.8.5 | Concrete | 1d | 2011-11-18 | 2011-11-18 | 161 | 0d |  |
| 163 | 1.1.6 | **5th Floor** | 20d | 2011-11-19 | 2011-12-09 |  | 0d |  |
| 164 | 1.1.6.1 | Layout Work | 1d | 2011-11-19 | 2011-11-19 | 162 | 0d |  |
| 165 | 1.1.6.2 | **Column (17 nos): Lift-1** | 4d | 2011-11-20 | 2011-11-23 |  | 1d |  |
| 166 | 1.1.6.2.1 | Re-bar | 1d | 2011-11-20 | 2011-11-20 | 164 | 1d | 0d |
| 167 | 1.1.6.2.2 | Formwork | 2d | 2011-11-21 | 2011-11-22 | 166 | 1d | 0d |
| 168 | 1.1.6.2.3 | Concrete | 1d | 2011-11-23 | 2011-11-23 | 167 | 1d | 0d |
| 169 | 1.1.6.3 | **Column (17 nos): Lift-2** | 4d | 2011-11-24 | 2011-11-27 |  | 1d |  |
| 170 | 1.1.6.3.1 | Re-bar | 1d | 2011-11-24 | 2011-11-24 | 168 | 1d | 0d |
| 171 | 1.1.6.3.2 | Formwork | 2d | 2011-11-25 | 2011-11-26 | 170 | 1d | 0d |
| 172 | 1.1.6.3.3 | Concrete | 1d | 2011-11-27 | 2011-11-27 | 171 | 1d |  |

| ID | WBS | Task | Duration | Start | Finish | Predecessors | Total slack | Free slack |
| --- | --- | --- | --- | --- | --- | --- | --- | --- |
| 173 | 1.1.6.4 | **Lift Core: Lift-1** | 5d | 2011-11-20 | 2011-11-24 |  | 0d |  |
| 174 | 1.1.6.4.1 | Re-bar | 2d | 2011-11-20 | 2011-11-21 | 164 | 0d |  |
| 175 | 1.1.6.4.2 | Formwork | 2d | 2011-11-22 | 2011-11-23 | 174 | 0d |  |
| 176 | 1.1.6.4.3 | Concrete | 1d | 2011-11-24 | 2011-11-24 | 175 | 0d |  |
| 177 | 1.1.6.5 | **Lift Core: Lift-2** | 4d | 2011-11-25 | 2011-11-28 |  | 0d |  |
| 178 | 1.1.6.5.1 | Re-bar | 1d | 2011-11-25 | 2011-11-25 | 176 | 0d |  |
| 179 | 1.1.6.5.2 | Formwork | 2d | 2011-11-26 | 2011-11-27 | 178 | 0d |  |
| 180 | 1.1.6.5.3 | Concrete | 1d | 2011-11-28 | 2011-11-28 | 179 | 0d |  |
| 181 | 1.1.6.6 | **Stair Case (2 nos)-Flight-1** | 8d | 2011-11-21 | 2011-11-28 |  | 331d |  |
| 182 | 1.1.6.6.1 | Formwork | 4d | 2011-11-21 | 2011-11-25 | 183SF, 164 | 335d |  |
| 183 | 1.1.6.6.2 | Re-bar | 3d | 2011-11-25 | 2011-11-28 | 184SF | 332d | 0d |
| 184 | 1.1.6.6.3 | Concrete | 1d | 2011-11-28 | 2011-11-28 | 180FF | 327d | 0d |
| 185 | 1.1.6.7 | **Stair Case (2 nos)-Flight-2** | 8d | 2011-12-01 | 2011-12-09 |  | 321d |  |
| 186 | 1.1.6.7.1 | Formwork | 4d | 2011-12-01 | 2011-12-05 | 187SF, 184 | 325d |  |
| 187 | 1.1.6.7.2 | Re-bar | 3d | 2011-12-05 | 2011-12-09 | 188SF | 322d | 0d |
| 188 | 1.1.6.7.3 | Concrete | 1d | 2011-12-09 | 2011-12-09 | 194FF | 321d | 0d |
| 189 | 1.1.6.8 | **Roof Slab** | 10d | 2011-11-29 | 2011-12-09 |  | 0d |  |
| 190 | 1.1.6.8.1 | Formwork | 5d | 2011-11-29 | 2011-12-03 | 172, 130FS+28d, 180 | 0d |  |
| 191 | 1.1.6.8.2 | Re-bar | 3d | 2011-12-04 | 2011-12-07 | 190 | 0d |  |
| 192 | 1.1.6.8.3 | MEP Work | 2d | 2011-12-07 | 2011-12-08 | 191FF+1d | 0d |  |
| 193 | 1.1.6.8.4 | Inspection | 1d | 2011-12-08 | 2011-12-08 | 192FF | 0d |  |
| 194 | 1.1.6.8.5 | Concrete | 1d | 2011-12-09 | 2011-12-09 | 193 | 0d |  |
| 195 | 1.1.7 | **6th Floor** | 20d | 2011-12-10 | 2011-12-31 |  | 0d |  |
| 196 | 1.1.7.1 | Layout Work | 1d | 2011-12-10 | 2011-12-10 | 194 | 0d |  |

| ID | WBS | Task | Duration | Start | Finish | Predecessors | Total slack | Free slack |
| --- | --- | --- | --- | --- | --- | --- | --- | --- |
| 197 | 1.1.7.2 | **Column (17 nos): Lift-1** | 4d | 2011-12-11 | 2011-12-14 |  | 1d |  |
| 198 | 1.1.7.2.1 | Re-bar | 1d | 2011-12-11 | 2011-12-11 | 196 | 1d | 0d |
| 199 | 1.1.7.2.2 | Formwork | 2d | 2011-12-12 | 2011-12-13 | 198 | 1d | 0d |
| 200 | 1.1.7.2.3 | Concrete | 1d | 2011-12-14 | 2011-12-14 | 199 | 1d | 0d |
| 201 | 1.1.7.3 | **Column (17 nos): Lift-2** | 4d | 2011-12-15 | 2011-12-19 |  | 1d |  |
| 202 | 1.1.7.3.1 | Re-bar | 1d | 2011-12-15 | 2011-12-15 | 200 | 1d | 0d |
| 203 | 1.1.7.3.2 | Formwork | 2d | 2011-12-17 | 2011-12-18 | 202 | 1d | 0d |
| 204 | 1.1.7.3.3 | Concrete | 1d | 2011-12-19 | 2011-12-19 | 203 | 1d |  |
| 205 | 1.1.7.4 | **Lift Core: Lift-1** | 5d | 2011-12-11 | 2011-12-15 |  | 0d |  |
| 206 | 1.1.7.4.1 | Re-bar | 2d | 2011-12-11 | 2011-12-12 | 196 | 0d |  |
| 207 | 1.1.7.4.2 | Formwork | 2d | 2011-12-13 | 2011-12-14 | 206 | 0d |  |
| 208 | 1.1.7.4.3 | Concrete | 1d | 2011-12-15 | 2011-12-15 | 207 | 0d |  |
| 209 | 1.1.7.5 | **Lift Core: Lift-2** | 4d | 2011-12-17 | 2011-12-20 |  | 0d |  |
| 210 | 1.1.7.5.1 | Re-bar | 1d | 2011-12-17 | 2011-12-17 | 208 | 0d |  |
| 211 | 1.1.7.5.2 | Formwork | 2d | 2011-12-18 | 2011-12-19 | 210 | 0d |  |
| 212 | 1.1.7.5.3 | Concrete | 1d | 2011-12-20 | 2011-12-20 | 211 | 0d |  |
| 213 | 1.1.7.6 | **Stair Case (2 nos)-Flight-1** | 8d | 2011-12-12 | 2011-12-20 |  | 311d |  |
| 214 | 1.1.7.6.1 | Formwork | 4d | 2011-12-12 | 2011-12-17 | 215SF, 196 | 315d |  |
| 215 | 1.1.7.6.2 | Re-bar | 3d | 2011-12-17 | 2011-12-20 | 216SF | 312d | 0d |
| 216 | 1.1.7.6.3 | Concrete | 1d | 2011-12-20 | 2011-12-20 | 212FF | 307d | 0d |
| 217 | 1.1.7.7 | **Stair Case (2 nos)-Flight-2** | 8d | 2011-12-23 | 2011-12-31 |  | 301d |  |
| 218 | 1.1.7.7.1 | Formwork | 4d | 2011-12-23 | 2011-12-28 | 219SF, 216 | 305d |  |
| 219 | 1.1.7.7.2 | Re-bar | 3d | 2011-12-28 | 2011-12-31 | 220SF | 302d | 0d |
| 220 | 1.1.7.7.3 | Concrete | 1d | 2011-12-31 | 2011-12-31 | 226FF | 301d | 0d |

| ID | WBS | Task | Duration | Start | Finish | Predecessors | Total slack | Free slack |
| --- | --- | --- | --- | --- | --- | --- | --- | --- |
| 221 | 1.1.7.8 | **Roof Slab** | 10d | 2011-12-21 | 2011-12-31 |  | 0d |  |
| 222 | 1.1.7.8.1 | Formwork | 5d | 2011-12-21 | 2011-12-26 | 204, 162FS+28d, 212 | 0d |  |
| 223 | 1.1.7.8.2 | Re-bar | 3d | 2011-12-27 | 2011-12-29 | 222 | 0d |  |
| 224 | 1.1.7.8.3 | MEP Work | 2d | 2011-12-29 | 2011-12-30 | 223FF+1d | 0d |  |
| 225 | 1.1.7.8.4 | Inspection | 1d | 2011-12-30 | 2011-12-30 | 224FF | 0d |  |
| 226 | 1.1.7.8.5 | Concrete | 1d | 2011-12-31 | 2011-12-31 | 225 | 0d |  |
| 227 | 1.1.8 | **7th Floor** | 20d | 2012-01-01 | 2012-01-20 |  | 0d |  |
| 228 | 1.1.8.1 | Layout Work | 1d | 2012-01-01 | 2012-01-01 | 226 | 0d |  |
| 229 | 1.1.8.2 | **Column (17 nos): Lift-1** | 4d | 2012-01-02 | 2012-01-05 |  | 1d |  |
| 230 | 1.1.8.2.1 | Re-bar | 1d | 2012-01-02 | 2012-01-02 | 228 | 1d | 0d |
| 231 | 1.1.8.2.2 | Formwork | 2d | 2012-01-03 | 2012-01-04 | 230 | 1d | 0d |
| 232 | 1.1.8.2.3 | Concrete | 1d | 2012-01-05 | 2012-01-05 | 231 | 1d | 0d |
| 233 | 1.1.8.3 | **Column (17 nos): Lift-2** | 4d | 2012-01-06 | 2012-01-09 |  | 1d |  |
| 234 | 1.1.8.3.1 | Re-bar | 1d | 2012-01-06 | 2012-01-06 | 232 | 1d | 0d |
| 235 | 1.1.8.3.2 | Formwork | 2d | 2012-01-07 | 2012-01-08 | 234 | 1d | 0d |
| 236 | 1.1.8.3.3 | Concrete | 1d | 2012-01-09 | 2012-01-09 | 235 | 1d |  |
| 237 | 1.1.8.4 | **Lift Core: Lift-1** | 5d | 2012-01-02 | 2012-01-06 |  | 0d |  |
| 238 | 1.1.8.4.1 | Re-bar | 2d | 2012-01-02 | 2012-01-03 | 228 | 0d |  |
| 239 | 1.1.8.4.2 | Formwork | 2d | 2012-01-04 | 2012-01-05 | 238 | 0d |  |
| 240 | 1.1.8.4.3 | Concrete | 1d | 2012-01-06 | 2012-01-06 | 239 | 0d |  |
| 241 | 1.1.8.5 | **Lift Core: Lift-2** | 4d | 2012-01-07 | 2012-01-10 |  | 0d |  |
| 242 | 1.1.8.5.1 | Re-bar | 1d | 2012-01-07 | 2012-01-07 | 240 | 0d |  |
| 243 | 1.1.8.5.2 | Formwork | 2d | 2012-01-08 | 2012-01-09 | 242 | 0d |  |
| 244 | 1.1.8.5.3 | Concrete | 1d | 2012-01-10 | 2012-01-10 | 243 | 0d |  |

| ID | WBS | Task | Duration | Start | Finish | Predecessors | Total slack | Free slack |
| --- | --- | --- | --- | --- | --- | --- | --- | --- |
| 245 | 1.1.8.6 | **Stair Case (2 nos)-Flight-1** | 8d | 2012-01-03 | 2012-01-10 |  | 291d |  |
| 246 | 1.1.8.6.1 | Formwork | 4d | 2012-01-03 | 2012-01-07 | 247SF, 228 | 295d |  |
| 247 | 1.1.8.6.2 | Re-bar | 3d | 2012-01-07 | 2012-01-10 | 248SF | 292d | 0d |
| 248 | 1.1.8.6.3 | Concrete | 1d | 2012-01-10 | 2012-01-10 | 244FF | 287d | 0d |
| 249 | 1.1.8.7 | **Stair Case (2 nos)-Flight-2** | 8d | 2012-01-13 | 2012-01-20 |  | 281d |  |
| 250 | 1.1.8.7.1 | Formwork | 4d | 2012-01-13 | 2012-01-17 | 251SF, 248 | 285d |  |
| 251 | 1.1.8.7.2 | Re-bar | 3d | 2012-01-17 | 2012-01-20 | 252SF | 282d | 0d |
| 252 | 1.1.8.7.3 | Concrete | 1d | 2012-01-20 | 2012-01-20 | 258FF | 281d | 0d |
| 253 | 1.1.8.8 | **Roof Slab** | 10d | 2012-01-11 | 2012-01-20 |  | 0d |  |
| 254 | 1.1.8.8.1 | Formwork | 5d | 2012-01-11 | 2012-01-15 | 236, 194FS+28d, 244 | 0d |  |
| 255 | 1.1.8.8.2 | Re-bar | 3d | 2012-01-16 | 2012-01-18 | 254 | 0d |  |
| 256 | 1.1.8.8.3 | MEP Work | 2d | 2012-01-18 | 2012-01-19 | 255FF+1d | 0d |  |
| 257 | 1.1.8.8.4 | Inspection | 1d | 2012-01-19 | 2012-01-19 | 256FF | 0d |  |
| 258 | 1.1.8.8.5 | Concrete | 1d | 2012-01-20 | 2012-01-20 | 257 | 0d |  |
| 259 | 1.1.9 | **8th Floor** | 20d | 2012-01-21 | 2012-02-10 |  | 0d |  |
| 260 | 1.1.9.1 | Layout Work | 1d | 2012-01-21 | 2012-01-21 | 258 | 0d |  |
| 261 | 1.1.9.2 | **Column (17 nos): Lift-1** | 4d | 2012-01-22 | 2012-01-25 |  | 1d |  |
| 262 | 1.1.9.2.1 | Re-bar | 1d | 2012-01-22 | 2012-01-22 | 260 | 1d | 0d |
| 263 | 1.1.9.2.2 | Formwork | 2d | 2012-01-23 | 2012-01-24 | 262 | 1d | 0d |
| 264 | 1.1.9.2.3 | Concrete | 1d | 2012-01-25 | 2012-01-25 | 263 | 1d | 0d |
| 265 | 1.1.9.3 | **Column (17 nos): Lift-2** | 4d | 2012-01-26 | 2012-01-29 |  | 1d |  |
| 266 | 1.1.9.3.1 | Re-bar | 1d | 2012-01-26 | 2012-01-26 | 264 | 1d | 0d |
| 267 | 1.1.9.3.2 | Formwork | 2d | 2012-01-27 | 2012-01-28 | 266 | 1d | 0d |
| 268 | 1.1.9.3.3 | Concrete | 1d | 2012-01-29 | 2012-01-29 | 267 | 1d |  |

| ID | WBS | Task | Duration | Start | Finish | Predecessors | Total slack | Free slack |
| --- | --- | --- | --- | --- | --- | --- | --- | --- |
| 269 | 1.1.9.4 | **Lift Core: Lift-1** | 5d | 2012-01-22 | 2012-01-26 |  | 0d |  |
| 270 | 1.1.9.4.1 | Re-bar | 2d | 2012-01-22 | 2012-01-23 | 260 | 0d |  |
| 271 | 1.1.9.4.2 | Formwork | 2d | 2012-01-24 | 2012-01-25 | 270 | 0d |  |
| 272 | 1.1.9.4.3 | Concrete | 1d | 2012-01-26 | 2012-01-26 | 271 | 0d |  |
| 273 | 1.1.9.5 | **Lift Core: Lift-2** | 4d | 2012-01-27 | 2012-01-30 |  | 0d |  |
| 274 | 1.1.9.5.1 | Re-bar | 1d | 2012-01-27 | 2012-01-27 | 272 | 0d |  |
| 275 | 1.1.9.5.2 | Formwork | 2d | 2012-01-28 | 2012-01-29 | 274 | 0d |  |
| 276 | 1.1.9.5.3 | Concrete | 1d | 2012-01-30 | 2012-01-30 | 275 | 0d |  |
| 277 | 1.1.9.6 | **Stair Case (2 nos)-Flight-1** | 8d | 2012-01-23 | 2012-01-30 |  | 271d |  |
| 278 | 1.1.9.6.1 | Formwork | 4d | 2012-01-23 | 2012-01-27 | 279SF, 260 | 275d |  |
| 279 | 1.1.9.6.2 | Re-bar | 3d | 2012-01-27 | 2012-01-30 | 280SF | 272d | 0d |
| 280 | 1.1.9.6.3 | Concrete | 1d | 2012-01-30 | 2012-01-30 | 276FF | 267d | 0d |
| 281 | 1.1.9.7 | **Stair Case (2 nos)-Flight-2** | 8d | 2012-02-02 | 2012-02-10 |  | 261d |  |
| 282 | 1.1.9.7.1 | Formwork | 4d | 2012-02-02 | 2012-02-07 | 283SF, 280 | 265d |  |
| 283 | 1.1.9.7.2 | Re-bar | 3d | 2012-02-07 | 2012-02-10 | 284SF | 262d | 0d |
| 284 | 1.1.9.7.3 | Concrete | 1d | 2012-02-10 | 2012-02-10 | 290FF | 261d | 0d |
| 285 | 1.1.9.8 | **Roof Slab** | 10d | 2012-01-31 | 2012-02-10 |  | 0d |  |
| 286 | 1.1.9.8.1 | Formwork | 5d | 2012-01-31 | 2012-02-04 | 268, 226FS+28d, 276 | 0d |  |
| 287 | 1.1.9.8.2 | Re-bar | 3d | 2012-02-05 | 2012-02-08 | 286 | 0d |  |
| 288 | 1.1.9.8.3 | MEP Work | 2d | 2012-02-08 | 2012-02-09 | 287FF+1d | 0d |  |
| 289 | 1.1.9.8.4 | Inspection | 1d | 2012-02-09 | 2012-02-09 | 288FF | 0d |  |
| 290 | 1.1.9.8.5 | Concrete | 1d | 2012-02-10 | 2012-02-10 | 289 | 0d |  |
| 291 | 1.1.10 | **9th Floor** | 20d | 2012-02-11 | 2012-03-02 |  | 0d |  |
| 292 | 1.1.10.1 | Layout Work | 1d | 2012-02-11 | 2012-02-11 | 290 | 0d |  |

| ID | WBS | Task | Duration | Start | Finish | Predecessors | Total slack | Free slack |
| --- | --- | --- | --- | --- | --- | --- | --- | --- |
| 293 | 1.1.10.2 | **Column (17 nos): Lift-1** | 4d | 2012-02-12 | 2012-02-15 |  | 1d |  |
| 294 | 1.1.10.2.1 | Re-bar | 1d | 2012-02-12 | 2012-02-12 | 292 | 1d | 0d |
| 295 | 1.1.10.2.2 | Formwork | 2d | 2012-02-13 | 2012-02-14 | 294 | 1d | 0d |
| 296 | 1.1.10.2.3 | Concrete | 1d | 2012-02-15 | 2012-02-15 | 295 | 1d | 0d |
| 297 | 1.1.10.3 | **Column (17 nos): Lift-2** | 4d | 2012-02-16 | 2012-02-19 |  | 1d |  |
| 298 | 1.1.10.3.1 | Re-bar | 1d | 2012-02-16 | 2012-02-16 | 296 | 1d | 0d |
| 299 | 1.1.10.3.2 | Formwork | 2d | 2012-02-17 | 2012-02-18 | 298 | 1d | 0d |
| 300 | 1.1.10.3.3 | Concrete | 1d | 2012-02-19 | 2012-02-19 | 299 | 1d |  |
| 301 | 1.1.10.4 | **Lift Core: Lift-1** | 5d | 2012-02-12 | 2012-02-16 |  | 0d |  |
| 302 | 1.1.10.4.1 | Re-bar | 2d | 2012-02-12 | 2012-02-13 | 292 | 0d |  |
| 303 | 1.1.10.4.2 | Formwork | 2d | 2012-02-14 | 2012-02-15 | 302 | 0d |  |
| 304 | 1.1.10.4.3 | Concrete | 1d | 2012-02-16 | 2012-02-16 | 303 | 0d |  |
| 305 | 1.1.10.5 | **Lift Core: Lift-2** | 4d | 2012-02-17 | 2012-02-20 |  | 0d |  |
| 306 | 1.1.10.5.1 | Re-bar | 1d | 2012-02-17 | 2012-02-17 | 304 | 0d |  |
| 307 | 1.1.10.5.2 | Formwork | 2d | 2012-02-18 | 2012-02-19 | 306 | 0d |  |
| 308 | 1.1.10.5.3 | Concrete | 1d | 2012-02-20 | 2012-02-20 | 307 | 0d |  |
| 309 | 1.1.10.6 | **Stair Case (2 nos)-Flight-1** | 8d | 2012-02-13 | 2012-02-20 |  | 251d |  |
| 310 | 1.1.10.6.1 | Formwork | 4d | 2012-02-13 | 2012-02-17 | 311SF, 292 | 255d |  |
| 311 | 1.1.10.6.2 | Re-bar | 3d | 2012-02-17 | 2012-02-20 | 312SF | 252d | 0d |
| 312 | 1.1.10.6.3 | Concrete | 1d | 2012-02-20 | 2012-02-20 | 308FF | 247d | 0d |
| 313 | 1.1.10.7 | **Stair Case (2 nos)-Flight-2** | 8d | 2012-02-24 | 2012-03-02 |  | 241d |  |
| 314 | 1.1.10.7.1 | Formwork | 4d | 2012-02-24 | 2012-02-28 | 315SF, 312 | 245d |  |
| 315 | 1.1.10.7.2 | Re-bar | 3d | 2012-02-28 | 2012-03-02 | 316SF | 242d | 0d |
| 316 | 1.1.10.7.3 | Concrete | 1d | 2012-03-02 | 2012-03-02 | 322FF | 241d | 0d |

| ID | WBS | Task | Duration | Start | Finish | Predecessors | Total slack | Free slack |
| --- | --- | --- | --- | --- | --- | --- | --- | --- |
| 317 | 1.1.10.8 | **Roof Slab** | 10d | 2012-02-22 | 2012-03-02 |  | 0d |  |
| 318 | 1.1.10.8.1 | Formwork | 5d | 2012-02-22 | 2012-02-26 | 300, 258FS+28d, 308 | 0d |  |
| 319 | 1.1.10.8.2 | Re-bar | 3d | 2012-02-27 | 2012-02-29 | 318 | 0d |  |
| 320 | 1.1.10.8.3 | MEP Work | 2d | 2012-02-29 | 2012-03-01 | 319FF+1d | 0d |  |
| 321 | 1.1.10.8.4 | Inspection | 1d | 2012-03-01 | 2012-03-01 | 320FF | 0d |  |
| 322 | 1.1.10.8.5 | Concrete | 1d | 2012-03-02 | 2012-03-02 | 321 | 0d |  |
| 323 | 1.1.11 | **10th Floor** | 20d | 2012-03-03 | 2012-03-23 |  | 0d |  |
| 324 | 1.1.11.1 | Layout Work | 1d | 2012-03-03 | 2012-03-03 | 322 | 0d |  |
| 325 | 1.1.11.2 | **Column (17 nos): Lift-1** | 4d | 2012-03-04 | 2012-03-07 |  | 1d |  |
| 326 | 1.1.11.2.1 | Re-bar | 1d | 2012-03-04 | 2012-03-04 | 324 | 1d | 0d |
| 327 | 1.1.11.2.2 | Formwork | 2d | 2012-03-05 | 2012-03-06 | 326 | 1d | 0d |
| 328 | 1.1.11.2.3 | Concrete | 1d | 2012-03-07 | 2012-03-07 | 327 | 1d | 0d |
| 329 | 1.1.11.3 | **Column (17 nos): Lift-2** | 4d | 2012-03-08 | 2012-03-11 |  | 1d |  |
| 330 | 1.1.11.3.1 | Re-bar | 1d | 2012-03-08 | 2012-03-08 | 328 | 1d | 0d |
| 331 | 1.1.11.3.2 | Formwork | 2d | 2012-03-09 | 2012-03-10 | 330 | 1d | 0d |
| 332 | 1.1.11.3.3 | Concrete | 1d | 2012-03-11 | 2012-03-11 | 331 | 1d |  |
| 333 | 1.1.11.4 | **Lift Core: Lift-1** | 5d | 2012-03-04 | 2012-03-08 |  | 0d |  |
| 334 | 1.1.11.4.1 | Re-bar | 2d | 2012-03-04 | 2012-03-05 | 324 | 0d |  |
| 335 | 1.1.11.4.2 | Formwork | 2d | 2012-03-06 | 2012-03-07 | 334 | 0d |  |
| 336 | 1.1.11.4.3 | Concrete | 1d | 2012-03-08 | 2012-03-08 | 335 | 0d |  |
| 337 | 1.1.11.5 | **Lift Core: Lift-2** | 4d | 2012-03-09 | 2012-03-12 |  | 0d |  |
| 338 | 1.1.11.5.1 | Re-bar | 1d | 2012-03-09 | 2012-03-09 | 336 | 0d |  |
| 339 | 1.1.11.5.2 | Formwork | 2d | 2012-03-10 | 2012-03-11 | 338 | 0d |  |
| 340 | 1.1.11.5.3 | Concrete | 1d | 2012-03-12 | 2012-03-12 | 339 | 0d |  |

| ID | WBS | Task | Duration | Start | Finish | Predecessors | Total slack | Free slack |
| --- | --- | --- | --- | --- | --- | --- | --- | --- |
| 341 | 1.1.11.6 | **Stair Case (2 nos)-Flight-1** | 8d | 2012-03-05 | 2012-03-12 |  | 231d |  |
| 342 | 1.1.11.6.1 | Formwork | 4d | 2012-03-05 | 2012-03-09 | 343SF, 324 | 235d |  |
| 343 | 1.1.11.6.2 | Re-bar | 3d | 2012-03-09 | 2012-03-12 | 344SF | 232d | 0d |
| 344 | 1.1.11.6.3 | Concrete | 1d | 2012-03-12 | 2012-03-12 | 340FF | 227d | 0d |
| 345 | 1.1.11.7 | **Stair Case (2 nos)-Flight-2** | 8d | 2012-03-15 | 2012-03-23 |  | 221d |  |
| 346 | 1.1.11.7.1 | Formwork | 4d | 2012-03-15 | 2012-03-20 | 347SF, 344 | 225d |  |
| 347 | 1.1.11.7.2 | Re-bar | 3d | 2012-03-20 | 2012-03-23 | 348SF | 222d | 0d |
| 348 | 1.1.11.7.3 | Concrete | 1d | 2012-03-23 | 2012-03-23 | 354FF | 221d | 0d |
| 349 | 1.1.11.8 | **Roof Slab** | 10d | 2012-03-13 | 2012-03-23 |  | 0d |  |
| 350 | 1.1.11.8.1 | Formwork | 5d | 2012-03-13 | 2012-03-18 | 332, 290FS+28d, 340 | 0d |  |
| 351 | 1.1.11.8.2 | Re-bar | 3d | 2012-03-19 | 2012-03-21 | 350 | 0d |  |
| 352 | 1.1.11.8.3 | MEP Work | 2d | 2012-03-21 | 2012-03-22 | 351FF+1d | 0d |  |
| 353 | 1.1.11.8.4 | Inspection | 1d | 2012-03-22 | 2012-03-22 | 352FF | 0d |  |
| 354 | 1.1.11.8.5 | Concrete | 1d | 2012-03-23 | 2012-03-23 | 353 | 0d |  |
| 355 | 1.1.12 | **11th Floor** | 20d | 2012-03-24 | 2012-04-12 |  | 0d |  |
| 356 | 1.1.12.1 | Layout Work | 1d | 2012-03-24 | 2012-03-24 | 354 | 0d |  |
| 357 | 1.1.12.2 | **Column (17 nos): Lift-1** | 4d | 2012-03-25 | 2012-03-28 |  | 1d |  |
| 358 | 1.1.12.2.1 | Re-bar | 1d | 2012-03-25 | 2012-03-25 | 356 | 1d | 0d |
| 359 | 1.1.12.2.2 | Formwork | 2d | 2012-03-26 | 2012-03-27 | 358 | 1d | 0d |
| 360 | 1.1.12.2.3 | Concrete | 1d | 2012-03-28 | 2012-03-28 | 359 | 1d | 0d |
| 361 | 1.1.12.3 | **Column (17 nos): Lift-2** | 4d | 2012-03-29 | 2012-04-01 |  | 1d |  |
| 362 | 1.1.12.3.1 | Re-bar | 1d | 2012-03-29 | 2012-03-29 | 360 | 1d | 0d |
| 363 | 1.1.12.3.2 | Formwork | 2d | 2012-03-30 | 2012-03-31 | 362 | 1d | 0d |
| 364 | 1.1.12.3.3 | Concrete | 1d | 2012-04-01 | 2012-04-01 | 363 | 1d |  |

| ID | WBS | Task | Duration | Start | Finish | Predecessors | Total slack | Free slack |
| --- | --- | --- | --- | --- | --- | --- | --- | --- |
| 365 | 1.1.12.4 | **Lift Core: Lift-1** | 5d | 2012-03-25 | 2012-03-29 |  | 0d |  |
| 366 | 1.1.12.4.1 | Re-bar | 2d | 2012-03-25 | 2012-03-26 | 356 | 0d |  |
| 367 | 1.1.12.4.2 | Formwork | 2d | 2012-03-27 | 2012-03-28 | 366 | 0d |  |
| 368 | 1.1.12.4.3 | Concrete | 1d | 2012-03-29 | 2012-03-29 | 367 | 0d |  |
| 369 | 1.1.12.5 | **Lift Core: Lift-2** | 4d | 2012-03-30 | 2012-04-02 |  | 0d |  |
| 370 | 1.1.12.5.1 | Re-bar | 1d | 2012-03-30 | 2012-03-30 | 368 | 0d |  |
| 371 | 1.1.12.5.2 | Formwork | 2d | 2012-03-31 | 2012-04-01 | 370 | 0d |  |
| 372 | 1.1.12.5.3 | Concrete | 1d | 2012-04-02 | 2012-04-02 | 371 | 0d |  |
| 373 | 1.1.12.6 | **Stair Case (2 nos)-Flight-1** | 8d | 2012-03-26 | 2012-04-02 |  | 211d |  |
| 374 | 1.1.12.6.1 | Formwork | 4d | 2012-03-26 | 2012-03-30 | 375SF, 356 | 215d |  |
| 375 | 1.1.12.6.2 | Re-bar | 3d | 2012-03-30 | 2012-04-02 | 376SF | 212d | 0d |
| 376 | 1.1.12.6.3 | Concrete | 1d | 2012-04-02 | 2012-04-02 | 372FF | 207d | 0d |
| 377 | 1.1.12.7 | **Stair Case (2 nos)-Flight-2** | 8d | 2012-04-05 | 2012-04-12 |  | 201d |  |
| 378 | 1.1.12.7.1 | Formwork | 4d | 2012-04-05 | 2012-04-09 | 379SF, 376 | 205d |  |
| 379 | 1.1.12.7.2 | Re-bar | 3d | 2012-04-09 | 2012-04-12 | 380SF | 202d | 0d |
| 380 | 1.1.12.7.3 | Concrete | 1d | 2012-04-12 | 2012-04-12 | 386FF | 201d | 0d |
| 381 | 1.1.12.8 | **Roof Slab** | 10d | 2012-04-03 | 2012-04-12 |  | 0d |  |
| 382 | 1.1.12.8.1 | Formwork | 5d | 2012-04-03 | 2012-04-07 | 364, 322FS+28d, 372 | 0d |  |
| 383 | 1.1.12.8.2 | Re-bar | 3d | 2012-04-08 | 2012-04-10 | 382 | 0d |  |
| 384 | 1.1.12.8.3 | MEP Work | 2d | 2012-04-10 | 2012-04-11 | 383FF+1d | 0d |  |
| 385 | 1.1.12.8.4 | Inspection | 1d | 2012-04-11 | 2012-04-11 | 384FF | 0d |  |
| 386 | 1.1.12.8.5 | Concrete | 1d | 2012-04-12 | 2012-04-12 | 385 | 0d |  |
| 387 | 1.1.13 | **12th Floor** | 20d | 2012-04-13 | 2012-05-04 |  | 0d |  |
| 388 | 1.1.13.1 | Layout Work | 1d | 2012-04-13 | 2012-04-13 | 386 | 0d |  |

| ID | WBS | Task | Duration | Start | Finish | Predecessors | Total slack | Free slack |
| --- | --- | --- | --- | --- | --- | --- | --- | --- |
| 389 | 1.1.13.2 | **Column (17 nos): Lift-1** | 4d | 2012-04-15 | 2012-04-18 |  | 1d |  |
| 390 | 1.1.13.2.1 | Re-bar | 1d | 2012-04-15 | 2012-04-15 | 388 | 1d | 0d |
| 391 | 1.1.13.2.2 | Formwork | 2d | 2012-04-16 | 2012-04-17 | 390 | 1d | 0d |
| 392 | 1.1.13.2.3 | Concrete | 1d | 2012-04-18 | 2012-04-18 | 391 | 1d | 0d |
| 393 | 1.1.13.3 | **Column (17 nos): Lift-2** | 4d | 2012-04-19 | 2012-04-22 |  | 1d |  |
| 394 | 1.1.13.3.1 | Re-bar | 1d | 2012-04-19 | 2012-04-19 | 392 | 1d | 0d |
| 395 | 1.1.13.3.2 | Formwork | 2d | 2012-04-20 | 2012-04-21 | 394 | 1d | 0d |
| 396 | 1.1.13.3.3 | Concrete | 1d | 2012-04-22 | 2012-04-22 | 395 | 1d |  |
| 397 | 1.1.13.4 | **Lift Core: Lift-1** | 5d | 2012-04-15 | 2012-04-19 |  | 0d |  |
| 398 | 1.1.13.4.1 | Re-bar | 2d | 2012-04-15 | 2012-04-16 | 388 | 0d |  |
| 399 | 1.1.13.4.2 | Formwork | 2d | 2012-04-17 | 2012-04-18 | 398 | 0d |  |
| 400 | 1.1.13.4.3 | Concrete | 1d | 2012-04-19 | 2012-04-19 | 399 | 0d |  |
| 401 | 1.1.13.5 | **Lift Core: Lift-2** | 4d | 2012-04-20 | 2012-04-23 |  | 0d |  |
| 402 | 1.1.13.5.1 | Re-bar | 1d | 2012-04-20 | 2012-04-20 | 400 | 0d |  |
| 403 | 1.1.13.5.2 | Formwork | 2d | 2012-04-21 | 2012-04-22 | 402 | 0d |  |
| 404 | 1.1.13.5.3 | Concrete | 1d | 2012-04-23 | 2012-04-23 | 403 | 0d |  |
| 405 | 1.1.13.6 | **Stair Case (2 nos)-Flight-1** | 8d | 2012-04-16 | 2012-04-23 |  | 191d |  |
| 406 | 1.1.13.6.1 | Formwork | 4d | 2012-04-16 | 2012-04-20 | 407SF, 388 | 195d |  |
| 407 | 1.1.13.6.2 | Re-bar | 3d | 2012-04-20 | 2012-04-23 | 408SF | 192d | 0d |
| 408 | 1.1.13.6.3 | Concrete | 1d | 2012-04-23 | 2012-04-23 | 404FF | 187d | 0d |
| 409 | 1.1.13.7 | **Stair Case (2 nos)-Flight-2** | 8d | 2012-04-26 | 2012-05-04 |  | 181d |  |
| 410 | 1.1.13.7.1 | Formwork | 4d | 2012-04-26 | 2012-04-30 | 411SF, 408 | 185d |  |
| 411 | 1.1.13.7.2 | Re-bar | 3d | 2012-04-30 | 2012-05-04 | 412SF | 182d | 0d |
| 412 | 1.1.13.7.3 | Concrete | 1d | 2012-05-04 | 2012-05-04 | 418FF | 181d | 0d |

| ID | WBS | Task | Duration | Start | Finish | Predecessors | Total slack | Free slack |
| --- | --- | --- | --- | --- | --- | --- | --- | --- |
| 413 | 1.1.13.8 | **Roof Slab** | 10d | 2012-04-24 | 2012-05-04 |  | 0d |  |
| 414 | 1.1.13.8.1 | Formwork | 5d | 2012-04-24 | 2012-04-28 | 396, 354FS+28d, 404 | 0d |  |
| 415 | 1.1.13.8.2 | Re-bar | 3d | 2012-04-29 | 2012-05-02 | 414 | 0d |  |
| 416 | 1.1.13.8.3 | MEP Work | 2d | 2012-05-02 | 2012-05-03 | 415FF+1d | 0d |  |
| 417 | 1.1.13.8.4 | Inspection | 1d | 2012-05-03 | 2012-05-03 | 416FF | 0d |  |
| 418 | 1.1.13.8.5 | Concrete | 1d | 2012-05-04 | 2012-05-04 | 417 | 0d |  |
| 419 | 1.1.14 | **13th Floor** | 20d | 2012-05-05 | 2012-05-25 |  | 0d |  |
| 420 | 1.1.14.1 | Layout Work | 1d | 2012-05-05 | 2012-05-05 | 418 | 0d |  |
| 421 | 1.1.14.2 | **Column (17 nos): Lift-1** | 4d | 2012-05-06 | 2012-05-09 |  | 1d |  |
| 422 | 1.1.14.2.1 | Re-bar | 1d | 2012-05-06 | 2012-05-06 | 420 | 1d | 0d |
| 423 | 1.1.14.2.2 | Formwork | 2d | 2012-05-07 | 2012-05-08 | 422 | 1d | 0d |
| 424 | 1.1.14.2.3 | Concrete | 1d | 2012-05-09 | 2012-05-09 | 423 | 1d | 0d |
| 425 | 1.1.14.3 | **Column (17 nos): Lift-2** | 4d | 2012-05-10 | 2012-05-13 |  | 1d |  |
| 426 | 1.1.14.3.1 | Re-bar | 1d | 2012-05-10 | 2012-05-10 | 424 | 1d | 0d |
| 427 | 1.1.14.3.2 | Formwork | 2d | 2012-05-11 | 2012-05-12 | 426 | 1d | 0d |
| 428 | 1.1.14.3.3 | Concrete | 1d | 2012-05-13 | 2012-05-13 | 427 | 1d |  |
| 429 | 1.1.14.4 | **Lift Core: Lift-1** | 5d | 2012-05-06 | 2012-05-10 |  | 0d |  |
| 430 | 1.1.14.4.1 | Re-bar | 2d | 2012-05-06 | 2012-05-07 | 420 | 0d |  |
| 431 | 1.1.14.4.2 | Formwork | 2d | 2012-05-08 | 2012-05-09 | 430 | 0d |  |
| 432 | 1.1.14.4.3 | Concrete | 1d | 2012-05-10 | 2012-05-10 | 431 | 0d |  |
| 433 | 1.1.14.5 | **Lift Core: Lift-2** | 4d | 2012-05-11 | 2012-05-14 |  | 0d |  |
| 434 | 1.1.14.5.1 | Re-bar | 1d | 2012-05-11 | 2012-05-11 | 432 | 0d |  |
| 435 | 1.1.14.5.2 | Formwork | 2d | 2012-05-12 | 2012-05-13 | 434 | 0d |  |
| 436 | 1.1.14.5.3 | Concrete | 1d | 2012-05-14 | 2012-05-14 | 435 | 0d |  |

| ID | WBS | Task | Duration | Start | Finish | Predecessors | Total slack | Free slack |
| --- | --- | --- | --- | --- | --- | --- | --- | --- |
| 437 | 1.1.14.6 | **Stair Case (2 nos)-Flight-1** | 8d | 2012-05-07 | 2012-05-14 |  | 171d |  |
| 438 | 1.1.14.6.1 | Formwork | 4d | 2012-05-07 | 2012-05-11 | 439SF, 420 | 175d |  |
| 439 | 1.1.14.6.2 | Re-bar | 3d | 2012-05-11 | 2012-05-14 | 440SF | 172d | 0d |
| 440 | 1.1.14.6.3 | Concrete | 1d | 2012-05-14 | 2012-05-14 | 436FF | 167d | 0d |
| 441 | 1.1.14.7 | **Stair Case (2 nos)-Flight-2** | 8d | 2012-05-18 | 2012-05-25 |  | 161d |  |
| 442 | 1.1.14.7.1 | Formwork | 4d | 2012-05-18 | 2012-05-22 | 443SF, 440 | 165d |  |
| 443 | 1.1.14.7.2 | Re-bar | 3d | 2012-05-22 | 2012-05-25 | 444SF | 162d | 0d |
| 444 | 1.1.14.7.3 | Concrete | 1d | 2012-05-25 | 2012-05-25 | 450FF | 161d | 0d |
| 445 | 1.1.14.8 | **Roof Slab** | 10d | 2012-05-15 | 2012-05-25 |  | 0d |  |
| 446 | 1.1.14.8.1 | Formwork | 5d | 2012-05-15 | 2012-05-20 | 428, 386FS+28d, 436 | 0d |  |
| 447 | 1.1.14.8.2 | Re-bar | 3d | 2012-05-21 | 2012-05-23 | 446 | 0d |  |
| 448 | 1.1.14.8.3 | MEP Work | 2d | 2012-05-23 | 2012-05-24 | 447FF+1d | 0d |  |
| 449 | 1.1.14.8.4 | Inspection | 1d | 2012-05-24 | 2012-05-24 | 448FF | 0d |  |
| 450 | 1.1.14.8.5 | Concrete | 1d | 2012-05-25 | 2012-05-25 | 449 | 0d |  |
| 451 | 1.1.15 | **Top Floor** | 20d | 2012-05-26 | 2012-06-14 |  | 0d |  |
| 452 | 1.1.15.1 | Layout Work | 1d | 2012-05-26 | 2012-05-26 | 450 | 0d |  |
| 453 | 1.1.15.2 | **Column (17 nos): Lift-1** | 4d | 2012-05-27 | 2012-05-30 |  | 1d |  |
| 454 | 1.1.15.2.1 | Re-bar | 1d | 2012-05-27 | 2012-05-27 | 452 | 1d | 0d |
| 455 | 1.1.15.2.2 | Formwork | 2d | 2012-05-28 | 2012-05-29 | 454 | 1d | 0d |
| 456 | 1.1.15.2.3 | Concrete | 1d | 2012-05-30 | 2012-05-30 | 455 | 1d | 0d |
| 457 | 1.1.15.3 | **Column (17 nos): Lift-2** | 4d | 2012-05-31 | 2012-06-03 |  | 1d |  |
| 458 | 1.1.15.3.1 | Re-bar | 1d | 2012-05-31 | 2012-05-31 | 456 | 1d | 0d |
| 459 | 1.1.15.3.2 | Formwork | 2d | 2012-06-01 | 2012-06-02 | 458 | 1d | 0d |
| 460 | 1.1.15.3.3 | Concrete | 1d | 2012-06-03 | 2012-06-03 | 459 | 1d |  |

| ID | WBS | Task | Duration | Start | Finish | Predecessors | Total slack | Free slack |
| --- | --- | --- | --- | --- | --- | --- | --- | --- |
| 461 | 1.1.15.4 | **Lift Core: Lift-1** | 5d | 2012-05-27 | 2012-05-31 |  | 0d |  |
| 462 | 1.1.15.4.1 | Re-bar | 2d | 2012-05-27 | 2012-05-28 | 452 | 0d |  |
| 463 | 1.1.15.4.2 | Formwork | 2d | 2012-05-29 | 2012-05-30 | 462 | 0d |  |
| 464 | 1.1.15.4.3 | Concrete | 1d | 2012-05-31 | 2012-05-31 | 463 | 0d |  |
| 465 | 1.1.15.5 | **Lift Core: Lift-2** | 4d | 2012-06-01 | 2012-06-04 |  | 0d |  |
| 466 | 1.1.15.5.1 | Re-bar | 1d | 2012-06-01 | 2012-06-01 | 464 | 0d |  |
| 467 | 1.1.15.5.2 | Formwork | 2d | 2012-06-02 | 2012-06-03 | 466 | 0d |  |
| 468 | 1.1.15.5.3 | Concrete | 1d | 2012-06-04 | 2012-06-04 | 467 | 0d |  |
| 469 | 1.1.15.6 | **Roof Slab** | 10d | 2012-06-05 | 2012-06-14 |  | 0d |  |
| 470 | 1.1.15.6.1 | Formwork | 5d | 2012-06-05 | 2012-06-09 | 460, 468, 418FS+28d | 0d |  |
| 471 | 1.1.15.6.2 | Re-bar | 3d | 2012-06-10 | 2012-06-12 | 470 | 0d |  |
| 472 | 1.1.15.6.3 | MEP Work | 2d | 2012-06-12 | 2012-06-13 | 471FF+1d | 0d |  |
| 473 | 1.1.15.6.4 | Inspection | 1d | 2012-06-13 | 2012-06-13 | 472FF | 0d |  |
| 474 | 1.1.15.6.5 | Concrete | 1d | 2012-06-14 | 2012-06-14 | 473 | 0d |  |
| 475 | 1.2 | **Masonry and Finishing Work** | 393d | 2011-07-28 | 2012-09-23 |  | 48d |  |
| 476 | 1.2.1 | **Slection of Contractor/ Supplier** | 135d | 2011-07-28 | 2011-12-27 |  | 306d |  |
| 477 | 1.2.1.1 | Masnory Work | 30d | 2011-07-28 | 2011-08-27 | 4SS | 310d | 0d |
| 478 | 1.2.1.2 | Tile Work | 30d | 2011-09-15 | 2011-10-16 | 506SF | 369d |  |
| 479 | 1.2.1.3 | MS Work | 30d | 2011-11-24 | 2011-12-27 | 511SF | 306d | 0d |
| 480 | 1.2.1.4 | SS Work | 30d | 2011-11-24 | 2011-12-27 | 479FF | 306d |  |
| 481 | 1.2.1.5 | Column Guard/ Car Stopper | 60d | 2011-08-23 | 2011-10-29 | 515SF | 356d |  |
| 482 | 1.2.1.6 | Resin Floor | 60d | 2011-09-05 | 2011-11-05 | 516SF | 349d |  |
| 483 | 1.2.1.7 | Painting | 30d | 2011-09-27 | 2011-10-28 | 517SF | 357d |  |
| 484 | 1.2.1.8 | Fire Door i/c LC | 90d | 2011-07-31 | 2011-11-12 | 533SF | 348d |  |

| ID | WBS | Task | Duration | Start | Finish | Predecessors | Total slack | Free slack |
| --- | --- | --- | --- | --- | --- | --- | --- | --- |
| 485 | 1.2.2 | **Basement-3** | 82d | 2011-09-22 | 2011-12-21 |  | 310d |  |
| 486 | 1.2.2.1 | Brick Work | 15d | 2011-09-22 | 2011-10-07 | 494FF+7d | 316d | 0d |
| 487 | 1.2.2.2 | Plaster | 10d | 2011-10-04 | 2011-10-14 | 486FF+7d | 316d | 0d |
| 488 | 1.2.2.3 | Pipe Covering | 15d | 2011-10-31 | 2011-11-20 | 773, 837, 899, 980 | 310d | 0d |
| 489 | 1.2.2.4 | Stair/ Other Railing/ Grill Work | 30d | 2011-10-16 | 2011-11-20 | 488FF | 310d | 0d |
| 490 | 1.2.2.5 | Column Guard/ Car Stopper | 7d | 2011-11-21 | 2011-11-27 | 489 | 310d | 0d |
| 491 | 1.2.2.6 | Resin Floor | 15d | 2011-11-28 | 2011-12-13 | 490 | 310d | 0d |
| 492 | 1.2.2.7 | Paniting | 30d | 2011-11-20 | 2011-12-21 | 491FF+7d | 310d |  |
| 493 | 1.2.3 | **Basement-2** | 69d | 2011-09-20 | 2011-12-04 |  | 316d |  |
| 494 | 1.2.3.1 | Brick Work | 10d | 2011-09-20 | 2011-09-29 | 502FF+7d | 316d | 0d |
| 495 | 1.2.3.2 | Plaster | 7d | 2011-09-28 | 2011-10-04 | 494FF+5d | 325d | 0d |
| 496 | 1.2.3.3 | Pipe Covering | 15d | 2011-10-16 | 2011-10-30 | 840, 902, 983, 779 | 325d | 0d |
| 497 | 1.2.3.4 | Stair/ Other Railing/ Grill Work | 30d | 2011-09-30 | 2011-10-30 | 496FF | 325d | 0d |
| 498 | 1.2.3.5 | Column Guard/ Car Stopper | 7d | 2011-10-31 | 2011-11-12 | 497 | 325d | 0d |
| 499 | 1.2.3.6 | Resin Floor | 15d | 2011-11-13 | 2011-11-27 | 498 | 325d | 0d |
| 500 | 1.2.3.7 | Paniting | 30d | 2011-10-30 | 2011-12-04 | 499FF+7d | 325d |  |
| 501 | 1.2.4 | **Basement-1** | 135d | 2011-09-03 | 2012-01-26 |  | 276d |  |
| 502 | 1.2.4.1 | Brick Work | 20d | 2011-09-03 | 2011-09-22 | 477 | 310d | 0d |
| 503 | 1.2.4.2 | Plaster | 15d | 2011-09-18 | 2011-10-02 | 502FF+10d | 310d | 0d |
| 504 | 1.2.4.3 | **Toilet Area** | 19d | 2011-10-14 | 2011-11-01 |  | 349d |  |
| 505 | 1.2.4.3.1 | Water Proofing Work | 2d | 2011-10-14 | 2011-10-15 | 779 | 349d | 0d |
| 506 | 1.2.4.3.2 | Tile Work/ Marble Top | 10d | 2011-10-16 | 2011-10-25 | 505 | 349d | 0d |
| 507 | 1.2.4.3.3 | Fixing Door | 3d | 2011-10-30 | 2011-11-01 | 508FF | 352d |  |
| 508 | 1.2.4.3.4 | False Ceiling Work | 7d | 2011-10-26 | 2011-11-01 | 779, 843, 905, 986, 506 | 349d | 0d |

| ID | WBS | Task | Duration | Start | Finish | Predecessors | Baseline start | Baseline finish | Baseline duration | Total slack | Free slack |
| --- | --- | --- | --- | --- | --- | --- | --- | --- | --- | --- | --- |
| 509 | 1.2.4.4 | **Substation** | 43d | 2011-12-12 | 2012-01-26 |  |  |  |  | 276d |  |
| 510 | 1.2.4.4.1 | Base/ Foundation | 15d | 2011-12-12 | 2011-12-29 | 913SF-28d, 511SF |  |  |  | 304d |  |
| 511 | 1.2.4.4.2 | MS Grill Work | 15d | 2011-12-27 | 2012-01-11 | 512SF |  |  |  | 291d | 0d |
| 512 | 1.2.4.4.3 | Paintimg Work | 15d | 2012-01-11 | 2012-01-26 | 913SF |  |  |  | 276d | 0d |
| 513 | 1.2.4.5 | Pipe Covering | 15d | 2011-10-14 | 2011-10-28 | 779, 843, 905, 986 |  |  |  | 327d | 0d |
| 514 | 1.2.4.6 | Stair/ Other Railing/ Grill Work | 30d | 2011-09-28 | 2011-10-28 | 513FF |  |  |  | 327d | 0d |
| 515 | 1.2.4.7 | Column Guard/ Car Stopper | 7d | 2011-10-29 | 2011-11-04 | 514 |  |  |  | 327d | 0d |
| 516 | 1.2.4.8 | Resin Floor | 15d | 2011-11-05 | 2011-11-25 | 515 |  |  |  | 327d | 0d |
| 517 | 1.2.4.9 | Paniting | 30d | 2011-10-28 | 2011-12-02 | 516FF+7d |  |  |  | 327d | 0d |
| 518 | 1.2.5 | **Ground Floor** | 152d | 2011-08-10 | 2012-01-25 |  |  |  |  | 276d |  |
| 519 | 1.2.5.1 | Architectural Design | 40d | 2011-08-10 | 2011-09-26 | 521SF |  |  |  | 388d |  |
| 520 | 1.2.5.2 | De-shuttering Roof Slab | 5d | 2011-09-21 | 2011-09-25 | 34FS+28d |  |  |  | 276d | 0d |
| 521 | 1.2.5.3 | Brick Work | 30d | 2011-09-26 | 2011-10-26 | 520 |  |  |  | 276d | 0d |
| 522 | 1.2.5.4 | Plaster | 20d | 2011-10-17 | 2011-11-05 | 521FF+10d |  |  |  | 276d | 0d |
| 523 | 1.2.5.5 | **Toilet Cubicals** | 18d | 2011-11-22 | 2011-12-10 | 522 | 2011-07-15 | 2011-07-26 | 0d? | 317d |  |
| 524 | 1.2.5.5.1 | Water Proofing Works | 3d | 2011-11-22 | 2011-11-24 | 782 | 2011-07-18 | 2011-07-19 | 0d? | 317d | 0d |
| 525 | 1.2.5.5.2 | Tile Works/ Marble Top | 10d | 2011-11-25 | 2011-12-04 | 524 | 2011-07-19 | 2011-07-22 | 0d? | 317d | 0d |
| 526 | 1.2.5.5.3 | Door/ Louver Install | 5d | 2011-12-05 | 2011-12-10 | 525 | 2011-07-22 | 2011-07-25 | 0d? | 317d | 0d |
| 527 | 1.2.5.6 | False Ceiling Works | 30d | 2011-12-13 | 2012-01-13 | 529, 782, 846, 924, 989 | 2011-08-14 | 2011-09-06 | 0d? | 288d |  |
| 528 | 1.2.5.7 | Paver Works | 30d | 2011-11-12 | 2011-12-12 | 522 | 2011-07-15 | 2011-07-30 | 0d? | 318d |  |
| 529 | 1.2.5.8 | Sone/Wood/Glazing in Wall | 30d | 2011-11-12 | 2011-12-12 | 522 | 2011-07-23 | 2011-08-07 | 0d? | 276d | 0d |
| 530 | 1.2.5.9 | Stair/Other Railing | 15d | 2011-11-12 | 2011-11-26 | 522 | 2011-07-22 | 2011-08-07 | 0d? | 333d |  |
| 531 | 1.2.5.10 | Granite Flooring | 20d | 2011-12-13 | 2012-01-03 | 529 | 2011-08-08 | 2011-08-18 | 0d? | 276d | 0d |
| 532 | 1.2.5.11 | Resin Floor | 15d | 2012-01-04 | 2012-01-18 | 531 | 2011-08-06 | 2011-08-21 | 0d? | 276d | 0d |
| 533 | 1.2.5.12 | Fire Door Installation | 7d | 2011-11-12 | 2011-11-18 | 522 | 2011-08-17 | 2011-08-24 | 0d? | 341d | 0d |
| 534 | 1.2.5.13 | Painting | 30d | 2011-12-27 | 2012-01-25 | 532FF+7d | 2011-08-13 | 2011-09-05 | 0d? | 276d |  |

| ID | WBS | Task | Duration | Start | Finish | Predecessors | Baseline start | Baseline finish | Baseline duration | Total slack | Free slack |
| --- | --- | --- | --- | --- | --- | --- | --- | --- | --- | --- | --- |
| 535 | 1.2.6 | **1st Floor** | 63d | 2011-10-12 | 2011-12-21 |  | 2011-07-23 | 2011-09-22 | 53d | 310d |  |
| 536 | 1.2.6.1 | De-shuttering Roof Slab | 5d | 2011-10-12 | 2011-10-16 | 66FS+28d | 2011-07-23 | 2011-07-26 | 0d? | 310d | 0d |
| 537 | 1.2.6.2 | Brick Work | 7d | 2011-10-17 | 2011-10-23 | 536 | 2011-07-26 | 2011-08-02 | 0d? | 310d | 0d |
| 538 | 1.2.6.3 | Plaster | 5d | 2011-10-24 | 2011-10-28 | 537 | 2011-08-02 | 2011-08-09 | 0d? | 310d | 0d |
| 539 | 1.2.6.4 | **Toilet Area** | 16d | 2011-11-05 | 2011-11-26 |  | 2011-08-09 | 2011-08-20 | 0d? | 330d |  |
| 540 | 1.2.6.4.1 | Water Proofing Works | 3d | 2011-11-05 | 2011-11-13 | 785 | 2011-08-12 | 2011-08-13 | 0d? | 330d | 0d |
| 541 | 1.2.6.4.2 | Tile Works/ Marble Top | 10d | 2011-11-14 | 2011-11-23 | 540 | 2011-08-13 | 2011-08-16 | 0d? | 330d | 0d |
| 542 | 1.2.6.4.3 | Door/ Louver Install | 3d | 2011-11-24 | 2011-11-26 | 541 | 2011-08-16 | 2011-08-19 | 0d? | 330d | 0d |
| 543 | 1.2.6.5 | False Ceiling Works | 15d | 2011-11-18 | 2011-12-02 | 544, 785, 849, 927, 992 | 2011-08-25 | 2011-09-17 | 0d? | 327d |  |
| 544 | 1.2.6.6 | Sone/Wood/Glazing in Wall | 14d | 2011-10-29 | 2011-11-17 | 538 | 2011-08-03 | 2011-08-18 | 0d? | 310d | 0d |
| 545 | 1.2.6.7 | Stair/Other Railing | 15d | 2011-10-29 | 2011-11-18 | 538 | 2011-08-02 | 2011-08-18 | 0d? | 341d |  |
| 546 | 1.2.6.8 | Granite Flooring | 10d | 2011-11-18 | 2011-11-27 | 544 | 2011-08-19 | 2011-09-06 | 0d? | 310d | 0d |
| 547 | 1.2.6.9 | Resin Floor | 15d | 2011-11-28 | 2011-12-13 | 546 | 2011-08-17 | 2011-09-09 | 0d? | 310d | 0d |
| 548 | 1.2.6.10 | Fire Door Installation | 7d | 2011-10-29 | 2011-11-04 | 538 | 2011-09-05 | 2011-09-12 | 0d? | 349d |  |
| 549 | 1.2.6.11 | Painting | 15d | 2011-12-05 | 2011-12-21 | 538FS+21d, 547FF+7d | 2011-09-07 | 2011-09-22 | 0d? | 310d |  |
| 550 | 1.2.7 | **2nd Floor** | 63d | 2011-11-01 | 2012-01-11 |  | 2011-07-23 | 2011-09-22 | 53d | 290d |  |
| 551 | 1.2.7.1 | De-shuttering Roof Slab | 5d | 2011-11-01 | 2011-11-05 | 98FS+28d | 2011-07-23 | 2011-07-26 | 0d? | 290d | 0d |
| 552 | 1.2.7.2 | Brick Work | 7d | 2011-11-12 | 2011-11-18 | 551 | 2011-07-26 | 2011-08-02 | 0d? | 290d | 0d |
| 553 | 1.2.7.3 | Plaster | 5d | 2011-11-19 | 2011-11-23 | 552 | 2011-08-02 | 2011-08-09 | 0d? | 290d | 0d |
| 554 | 1.2.7.4 | **Toilet Area** | 16d | 2011-12-01 | 2011-12-18 |  | 2011-08-09 | 2011-08-20 | 0d? | 310d |  |
| 555 | 1.2.7.4.1 | Water Proofing Works | 3d | 2011-12-01 | 2011-12-03 | 788 | 2011-08-12 | 2011-08-13 | 0d? | 310d | 0d |
| 556 | 1.2.7.4.2 | Tile Works/ Marble Top | 10d | 2011-12-04 | 2011-12-14 | 555 | 2011-08-13 | 2011-08-16 | 0d? | 310d | 0d |
| 557 | 1.2.7.4.3 | Door/ Louver Install | 3d | 2011-12-15 | 2011-12-18 | 556 | 2011-08-16 | 2011-08-19 | 0d? | 310d | 0d |
| 558 | 1.2.7.5 | False Ceiling Works | 15d | 2011-12-09 | 2011-12-24 | 559, 788, 849, 930, 995 | 2011-08-25 | 2011-09-17 | 0d? | 307d |  |
| 559 | 1.2.7.6 | Sone/Wood/Glazing in Wall | 14d | 2011-11-24 | 2011-12-08 | 553 | 2011-08-03 | 2011-08-18 | 0d? | 290d | 0d |
| 560 | 1.2.7.7 | Stair/Other Railing | 15d | 2011-11-24 | 2011-12-09 | 553 | 2011-08-02 | 2011-08-18 | 0d? | 321d |  |
| 561 | 1.2.7.8 | Granite Flooring | 10d | 2011-12-09 | 2011-12-19 | 559 | 2011-08-19 | 2011-09-06 | 0d? | 290d | 0d |
| 562 | 1.2.7.9 | Resin Floor | 15d | 2011-12-20 | 2012-01-04 | 561 | 2011-08-17 | 2011-09-09 | 0d? | 290d | 0d |
| 563 | 1.2.7.10 | Fire Door Installation | 7d | 2011-11-24 | 2011-11-30 | 553 | 2011-09-05 | 2011-09-12 | 0d? | 329d |  |
| 564 | 1.2.7.11 | Painting | 15d | 2011-12-28 | 2012-01-11 | 553FS+21d, 562FF+7d | 2011-09-07 | 2011-09-22 | 0d? | 290d |  |

| ID | WBS | Task | Duration | Start | Finish | Predecessors | Baseline start | Baseline finish | Baseline duration | Total slack | Free slack |
| --- | --- | --- | --- | --- | --- | --- | --- | --- | --- | --- | --- |
| 565 | 1.2.8 | **3rd Floor** | 63d | 2011-11-27 | 2012-01-31 |  | 2011-07-23 | 2011-09-22 | 53d | 270d |  |
| 566 | 1.2.8.1 | De-shuttering Roof Slab | 5d | 2011-11-27 | 2011-12-01 | 130FS+28d | 2011-07-23 | 2011-07-26 | 0d? | 270d | 0d |
| 567 | 1.2.8.2 | Brick Work | 7d | 2011-12-02 | 2011-12-09 | 566 | 2011-07-26 | 2011-08-02 | 0d? | 270d | 0d |
| 568 | 1.2.8.3 | Plaster | 5d | 2011-12-10 | 2011-12-14 | 567 | 2011-08-02 | 2011-08-09 | 0d? | 270d | 0d |
| 569 | 1.2.8.4 | **Toilet Area** | 16d | 2011-12-23 | 2012-01-08 |  | 2011-08-09 | 2011-08-20 | 0d? | 290d |  |
| 570 | 1.2.8.4.1 | Water Proofing Works | 3d | 2011-12-23 | 2011-12-26 | 791 | 2011-08-12 | 2011-08-13 | 0d? | 290d | 0d |
| 571 | 1.2.8.4.2 | Tile Works/ Marble Top | 10d | 2011-12-27 | 2012-01-05 | 570 | 2011-08-13 | 2011-08-16 | 0d? | 290d | 0d |
| 572 | 1.2.8.4.3 | Door/ Louver Install | 3d | 2012-01-06 | 2012-01-08 | 571 | 2011-08-16 | 2011-08-19 | 0d? | 290d | 0d |
| 573 | 1.2.8.5 | False Ceiling Works | 15d | 2011-12-31 | 2012-01-14 | 574, 791, 855, 934, 999 | 2011-08-25 | 2011-09-17 | 0d? | 287d |  |
| 574 | 1.2.8.6 | Sone/Wood/Glazing in Wall | 14d | 2011-12-15 | 2011-12-30 | 568 | 2011-08-03 | 2011-08-18 | 0d? | 270d | 0d |
| 575 | 1.2.8.7 | Stair/Other Railing | 15d | 2011-12-15 | 2011-12-31 | 568 | 2011-08-02 | 2011-08-18 | 0d? | 301d |  |
| 576 | 1.2.8.8 | Granite Flooring | 10d | 2011-12-31 | 2012-01-09 | 574 | 2011-08-19 | 2011-09-06 | 0d? | 270d | 0d |
| 577 | 1.2.8.9 | Resin Floor | 15d | 2012-01-10 | 2012-01-24 | 576 | 2011-08-17 | 2011-09-09 | 0d? | 270d | 0d |
| 578 | 1.2.8.10 | Fire Door Installation | 7d | 2011-12-15 | 2011-12-22 | 568 | 2011-09-05 | 2011-09-12 | 0d? | 309d |  |
| 579 | 1.2.8.11 | Painting | 15d | 2012-01-17 | 2012-01-31 | 568FS+21d, 577FF+7d | 2011-09-07 | 2011-09-22 | 0d? | 270d |  |
| 580 | 1.2.9 | **4th Floor** | 63d | 2011-12-19 | 2012-02-22 |  | 2011-07-23 | 2011-09-22 | 53d | 250d |  |
| 581 | 1.2.9.1 | De-shuttering Roof Slab | 5d | 2011-12-19 | 2011-12-23 | 162FS+28d | 2011-07-23 | 2011-07-26 | 0d? | 250d | 0d |
| 582 | 1.2.9.2 | Brick Work | 7d | 2011-12-24 | 2011-12-31 | 581 | 2011-07-26 | 2011-08-02 | 0d? | 250d | 0d |
| 583 | 1.2.9.3 | Plaster | 5d | 2012-01-01 | 2012-01-05 | 582 | 2011-08-02 | 2011-08-09 | 0d? | 250d | 0d |
| 584 | 1.2.9.4 | **Toilet Area** | 16d | 2012-01-13 | 2012-01-28 |  | 2011-08-09 | 2011-08-20 | 0d? | 270d |  |
| 585 | 1.2.9.4.1 | Water Proofing Works | 3d | 2012-01-13 | 2012-01-15 | 794 | 2011-08-12 | 2011-08-13 | 0d? | 270d | 0d |
| 586 | 1.2.9.4.2 | Tile Works/ Marble Top | 10d | 2012-01-16 | 2012-01-25 | 585 | 2011-08-13 | 2011-08-16 | 0d? | 270d | 0d |
| 587 | 1.2.9.4.3 | Door/ Louver Install | 3d | 2012-01-26 | 2012-01-28 | 586 | 2011-08-16 | 2011-08-19 | 0d? | 270d | 0d |
| 588 | 1.2.9.5 | False Ceiling Works | 15d | 2012-01-20 | 2012-02-03 | 589, 794, 858, 936, 1001 | 2011-08-25 | 2011-09-17 | 0d? | 267d |  |
| 589 | 1.2.9.6 | Sone/Wood/Glazing in Wall | 14d | 2012-01-06 | 2012-01-19 | 583 | 2011-08-03 | 2011-08-18 | 0d? | 250d | 0d |
| 590 | 1.2.9.7 | Stair/Other Railing | 15d | 2012-01-06 | 2012-01-20 | 583 | 2011-08-02 | 2011-08-18 | 0d? | 281d |  |
| 591 | 1.2.9.8 | Granite Flooring | 10d | 2012-01-20 | 2012-01-29 | 589 | 2011-08-19 | 2011-09-06 | 0d? | 250d | 0d |
| 592 | 1.2.9.9 | Resin Floor | 15d | 2012-01-30 | 2012-02-14 | 591 | 2011-08-17 | 2011-09-09 | 0d? | 250d | 0d |
| 593 | 1.2.9.10 | Fire Door Installation | 7d | 2012-01-06 | 2012-01-12 | 583 | 2011-09-05 | 2011-09-12 | 0d? | 289d |  |
| 594 | 1.2.9.11 | Painting | 15d | 2012-02-07 | 2012-02-22 | 583FS+21d, 592FF+7d | 2011-09-07 | 2011-09-22 | 0d? | 250d |  |

| ID | WBS | Task | Duration | Start | Finish | Predecessors | Baseline start | Baseline finish | Baseline duration | Total slack | Free slack |
| --- | --- | --- | --- | --- | --- | --- | --- | --- | --- | --- | --- |
| 595 | 1.2.10 | **5th Floor** | 63d | 2012-01-09 | 2012-03-13 |  | 2011-07-23 | 2011-09-22 | 53d | 230d |  |
| 596 | 1.2.10.1 | De-shuttering Roof Slab | 5d | 2012-01-09 | 2012-01-13 | 194FS+28d | 2011-07-23 | 2011-07-26 | 0d? | 230d | 0d |
| 597 | 1.2.10.2 | Brick Work | 7d | 2012-01-14 | 2012-01-20 | 596 | 2011-07-26 | 2011-08-02 | 0d? | 230d | 0d |
| 598 | 1.2.10.3 | Plaster | 5d | 2012-01-21 | 2012-01-25 | 597 | 2011-08-02 | 2011-08-09 | 0d? | 230d | 0d |
| 599 | 1.2.10.4 | **Toilet Area** | 16d | 2012-02-02 | 2012-02-18 |  | 2011-08-09 | 2011-08-20 | 0d? | 250d |  |
| 600 | 1.2.10.4.1 | Water Proofing Works | 3d | 2012-02-02 | 2012-02-04 | 797 | 2011-08-12 | 2011-08-13 | 0d? | 250d | 0d |
| 601 | 1.2.10.4.2 | Tile Works/ Marble Top | 10d | 2012-02-05 | 2012-02-15 | 600 | 2011-08-13 | 2011-08-16 | 0d? | 250d | 0d |
| 602 | 1.2.10.4.3 | Door/ Louver Install | 3d | 2012-02-16 | 2012-02-18 | 601 | 2011-08-16 | 2011-08-19 | 0d? | 250d | 0d |
| 603 | 1.2.10.5 | False Ceiling Works | 15d | 2012-02-10 | 2012-02-25 | 604, 797, 861, 939, 1004 | 2011-08-25 | 2011-09-17 | 0d? | 247d |  |
| 604 | 1.2.10.6 | Sone/Wood/Glazing in Wall | 14d | 2012-01-26 | 2012-02-09 | 598 | 2011-08-03 | 2011-08-18 | 0d? | 230d | 0d |
| 605 | 1.2.10.7 | Stair/Other Railing | 15d | 2012-01-26 | 2012-02-10 | 598 | 2011-08-02 | 2011-08-18 | 0d? | 261d |  |
| 606 | 1.2.10.8 | Granite Flooring | 10d | 2012-02-10 | 2012-02-19 | 604 | 2011-08-19 | 2011-09-06 | 0d? | 230d | 0d |
| 607 | 1.2.10.9 | Resin Floor | 15d | 2012-02-20 | 2012-03-06 | 606 | 2011-08-17 | 2011-09-09 | 0d? | 230d | 0d |
| 608 | 1.2.10.10 | Fire Door Installation | 7d | 2012-01-26 | 2012-02-01 | 598 | 2011-09-05 | 2011-09-12 | 0d? | 269d |  |
| 609 | 1.2.10.11 | Painting | 15d | 2012-02-28 | 2012-03-13 | 598FS+21d, 607FF+7d | 2011-09-07 | 2011-09-22 | 0d? | 230d |  |
| 610 | 1.2.11 | **6th Floor** | 63d | 2012-01-29 | 2012-04-03 |  | 2011-07-23 | 2011-09-22 | 53d | 210d |  |
| 611 | 1.2.11.1 | De-shuttering Roof Slab | 5d | 2012-01-29 | 2012-02-02 | 226FS+28d | 2011-07-23 | 2011-07-26 | 0d? | 210d | 0d |
| 612 | 1.2.11.2 | Brick Work | 7d | 2012-02-03 | 2012-02-10 | 611 | 2011-07-26 | 2011-08-02 | 0d? | 210d | 0d |
| 613 | 1.2.11.3 | Plaster | 5d | 2012-02-11 | 2012-02-15 | 612 | 2011-08-02 | 2011-08-09 | 0d? | 210d | 0d |
| 614 | 1.2.11.4 | **Toilet Area** | 16d | 2012-02-24 | 2012-03-10 |  | 2011-08-09 | 2011-08-20 | 0d? | 230d |  |
| 615 | 1.2.11.4.1 | Water Proofing Works | 3d | 2012-02-24 | 2012-02-26 | 800 | 2011-08-12 | 2011-08-13 | 0d? | 230d | 0d |
| 616 | 1.2.11.4.2 | Tile Works/ Marble Top | 10d | 2012-02-27 | 2012-03-07 | 615 | 2011-08-13 | 2011-08-16 | 0d? | 230d | 0d |
| 617 | 1.2.11.4.3 | Door/ Louver Install | 3d | 2012-03-08 | 2012-03-10 | 616 | 2011-08-16 | 2011-08-19 | 0d? | 230d | 0d |
| 618 | 1.2.11.5 | False Ceiling Works | 15d | 2012-03-02 | 2012-03-16 | 619, 800, 864, 942, 1007 | 2011-08-25 | 2011-09-17 | 0d? | 227d |  |
| 619 | 1.2.11.6 | Sone/Wood/Glazing in Wall | 14d | 2012-02-16 | 2012-03-01 | 613 | 2011-08-03 | 2011-08-18 | 0d? | 210d | 0d |
| 620 | 1.2.11.7 | Stair/Other Railing | 15d | 2012-02-16 | 2012-03-02 | 613 | 2011-08-02 | 2011-08-18 | 0d? | 241d |  |
| 621 | 1.2.11.8 | Granite Flooring | 10d | 2012-03-02 | 2012-03-11 | 619 | 2011-08-19 | 2011-09-06 | 0d? | 210d | 0d |
| 622 | 1.2.11.9 | Resin Floor | 15d | 2012-03-12 | 2012-03-27 | 621 | 2011-08-17 | 2011-09-09 | 0d? | 210d | 0d |
| 623 | 1.2.11.10 | Fire Door Installation | 7d | 2012-02-16 | 2012-02-23 | 613 | 2011-09-05 | 2011-09-12 | 0d? | 249d |  |
| 624 | 1.2.11.11 | Painting | 15d | 2012-03-20 | 2012-04-03 | 613FS+21d, 622FF+7d | 2011-09-07 | 2011-09-22 | 0d? | 210d |  |

| ID | WBS | Task | Duration | Start | Finish | Predecessors | Baseline start | Baseline finish | Baseline duration | Total slack | Free slack |
| --- | --- | --- | --- | --- | --- | --- | --- | --- | --- | --- | --- |
| 625 | 1.2.12 | **7th Floor** | 63d | 2012-02-19 | 2012-04-24 |  | 2011-07-23 | 2011-09-22 | 53d | 190d |  |
| 626 | 1.2.12.1 | De-shuttering Roof Slab | 5d | 2012-02-19 | 2012-02-24 | 258FS+28d | 2011-07-23 | 2011-07-26 | 0d? | 190d | 0d |
| 627 | 1.2.12.2 | Brick Work | 7d | 2012-02-25 | 2012-03-02 | 626 | 2011-07-26 | 2011-08-02 | 0d? | 190d | 0d |
| 628 | 1.2.12.3 | Plaster | 5d | 2012-03-03 | 2012-03-07 | 627 | 2011-08-02 | 2011-08-09 | 0d? | 190d | 0d |
| 629 | 1.2.12.4 | **Toilet Area** | 16d | 2012-03-15 | 2012-03-31 |  | 2011-08-09 | 2011-08-20 | 0d? | 210d |  |
| 630 | 1.2.12.4.1 | Water Proofing Works | 3d | 2012-03-15 | 2012-03-18 | 803 | 2011-08-12 | 2011-08-13 | 0d? | 210d | 0d |
| 631 | 1.2.12.4.2 | Tile Works/ Marble Top | 10d | 2012-03-19 | 2012-03-28 | 630 | 2011-08-13 | 2011-08-16 | 0d? | 210d | 0d |
| 632 | 1.2.12.4.3 | Door/ Louver Install | 3d | 2012-03-29 | 2012-03-31 | 631 | 2011-08-16 | 2011-08-19 | 0d? | 210d | 0d |
| 633 | 1.2.12.5 | False Ceiling Works | 15d | 2012-03-23 | 2012-04-06 | 634, 803, 867, 945, 1010 | 2011-08-25 | 2011-09-17 | 0d? | 207d |  |
| 634 | 1.2.12.6 | Sone/Wood/Glazing in Wall | 14d | 2012-03-08 | 2012-03-22 | 628 | 2011-08-03 | 2011-08-18 | 0d? | 190d | 0d |
| 635 | 1.2.12.7 | Stair/Other Railing | 15d | 2012-03-08 | 2012-03-23 | 628 | 2011-08-02 | 2011-08-18 | 0d? | 221d |  |
| 636 | 1.2.12.8 | Granite Flooring | 10d | 2012-03-23 | 2012-04-01 | 634 | 2011-08-19 | 2011-09-06 | 0d? | 190d | 0d |
| 637 | 1.2.12.9 | Resin Floor | 15d | 2012-04-02 | 2012-04-17 | 636 | 2011-08-17 | 2011-09-09 | 0d? | 190d | 0d |
| 638 | 1.2.12.10 | Fire Door Installation | 7d | 2012-03-08 | 2012-03-14 | 628 | 2011-09-05 | 2011-09-12 | 0d? | 229d |  |
| 639 | 1.2.12.11 | Painting | 15d | 2012-04-09 | 2012-04-24 | 628FS+21d, 637FF+7d | 2011-09-07 | 2011-09-22 | 0d? | 190d |  |
| 640 | 1.2.13 | **8th Floor** | 63d | 2012-03-11 | 2012-05-15 |  | 2011-07-23 | 2011-09-22 | 53d | 170d |  |
| 641 | 1.2.13.1 | De-shuttering Roof Slab | 5d | 2012-03-11 | 2012-03-15 | 290FS+28d | 2011-07-23 | 2011-07-26 | 0d? | 170d | 0d |
| 642 | 1.2.13.2 | Brick Work | 7d | 2012-03-16 | 2012-03-23 | 641 | 2011-07-26 | 2011-08-02 | 0d? | 170d | 0d |
| 643 | 1.2.13.3 | Plaster | 5d | 2012-03-24 | 2012-03-28 | 642 | 2011-08-02 | 2011-08-09 | 0d? | 170d | 0d |
| 644 | 1.2.13.4 | **Toilet Area** | 16d | 2012-04-05 | 2012-04-21 |  | 2011-08-09 | 2011-08-20 | 0d? | 190d |  |
| 645 | 1.2.13.4.1 | Water Proofing Works | 3d | 2012-04-05 | 2012-04-07 | 806 | 2011-08-12 | 2011-08-13 | 0d? | 190d | 0d |
| 646 | 1.2.13.4.2 | Tile Works/ Marble Top | 10d | 2012-04-08 | 2012-04-18 | 645 | 2011-08-13 | 2011-08-16 | 0d? | 190d | 0d |
| 647 | 1.2.13.4.3 | Door/ Louver Install | 3d | 2012-04-19 | 2012-04-21 | 646 | 2011-08-16 | 2011-08-19 | 0d? | 190d | 0d |
| 648 | 1.2.13.5 | False Ceiling Works | 15d | 2012-04-12 | 2012-04-27 | 649, 806, 870, 948, 1013 | 2011-08-25 | 2011-09-17 | 0d? | 187d |  |
| 649 | 1.2.13.6 | Sone/Wood/Glazing in Wall | 14d | 2012-03-29 | 2012-04-11 | 643 | 2011-08-03 | 2011-08-18 | 0d? | 170d | 0d |
| 650 | 1.2.13.7 | Stair/Other Railing | 15d | 2012-03-29 | 2012-04-12 | 643 | 2011-08-02 | 2011-08-18 | 0d? | 201d |  |
| 651 | 1.2.13.8 | Granite Flooring | 10d | 2012-04-12 | 2012-04-22 | 649 | 2011-08-19 | 2011-09-06 | 0d? | 170d | 0d |
| 652 | 1.2.13.9 | Resin Floor | 15d | 2012-04-23 | 2012-05-08 | 651 | 2011-08-17 | 2011-09-09 | 0d? | 170d | 0d |
| 653 | 1.2.13.10 | Fire Door Installation | 7d | 2012-03-29 | 2012-04-04 | 643 | 2011-09-05 | 2011-09-12 | 0d? | 209d |  |
| 654 | 1.2.13.11 | Painting | 15d | 2012-04-30 | 2012-05-15 | 643FS+21d, 652FF+7d | 2011-09-07 | 2011-09-22 | 0d? | 170d |  |

| ID | WBS | Task | Duration | Start | Finish | Predecessors | Baseline start | Baseline finish | Baseline duration | Total slack | Free slack |
| --- | --- | --- | --- | --- | --- | --- | --- | --- | --- | --- | --- |
| 655 | 1.2.14 | **9th Floor** | 63d | 2012-04-01 | 2012-06-05 |  | 2011-07-23 | 2011-09-22 | 53d | 150d |  |
| 656 | 1.2.14.1 | De-shuttering Roof Slab | 5d | 2012-04-01 | 2012-04-05 | 322FS+28d | 2011-07-23 | 2011-07-26 | 0d? | 150d | 0d |
| 657 | 1.2.14.2 | Brick Work | 7d | 2012-04-06 | 2012-04-12 | 656 | 2011-07-26 | 2011-08-02 | 0d? | 150d | 0d |
| 658 | 1.2.14.3 | Plaster | 5d | 2012-04-13 | 2012-04-18 | 657 | 2011-08-02 | 2011-08-09 | 0d? | 150d | 0d |
| 659 | 1.2.14.4 | **Toilet Area** | 16d | 2012-04-26 | 2012-05-12 |  | 2011-08-09 | 2011-08-20 | 0d? | 170d |  |
| 660 | 1.2.14.4.1 | Water Proofing Works | 3d | 2012-04-26 | 2012-04-28 | 809 | 2011-08-12 | 2011-08-13 | 0d? | 170d | 0d |
| 661 | 1.2.14.4.2 | Tile Works/ Marble Top | 10d | 2012-04-29 | 2012-05-09 | 660 | 2011-08-13 | 2011-08-16 | 0d? | 170d | 0d |
| 662 | 1.2.14.4.3 | Door/ Louver Install | 3d | 2012-05-10 | 2012-05-12 | 661 | 2011-08-16 | 2011-08-19 | 0d? | 170d | 0d |
| 663 | 1.2.14.5 | False Ceiling Works | 15d | 2012-05-04 | 2012-05-19 | 664, 809, 873, 951, 1016 | 2011-08-25 | 2011-09-17 | 0d? | 167d |  |
| 664 | 1.2.14.6 | Sone/Wood/Glazing in Wall | 14d | 2012-04-19 | 2012-05-03 | 658 | 2011-08-03 | 2011-08-18 | 0d? | 150d | 0d |
| 665 | 1.2.14.7 | Stair/Other Railing | 15d | 2012-04-19 | 2012-05-04 | 658 | 2011-08-02 | 2011-08-18 | 0d? | 181d |  |
| 666 | 1.2.14.8 | Granite Flooring | 10d | 2012-05-04 | 2012-05-13 | 664 | 2011-08-19 | 2011-09-06 | 0d? | 150d | 0d |
| 667 | 1.2.14.9 | Resin Floor | 15d | 2012-05-14 | 2012-05-29 | 666 | 2011-08-17 | 2011-09-09 | 0d? | 150d | 0d |
| 668 | 1.2.14.10 | Fire Door Installation | 7d | 2012-04-19 | 2012-04-25 | 658 | 2011-09-05 | 2011-09-12 | 0d? | 189d |  |
| 669 | 1.2.14.11 | Painting | 15d | 2012-05-22 | 2012-06-05 | 658FS+21d, 667FF+7d | 2011-09-07 | 2011-09-22 | 0d? | 150d |  |
| 670 | 1.2.15 | **10th Floor** | 63d | 2012-04-22 | 2012-06-25 |  | 2011-07-23 | 2011-09-22 | 53d | 130d |  |
| 671 | 1.2.15.1 | De-shuttering Roof Slab | 5d | 2012-04-22 | 2012-04-26 | 354FS+28d | 2011-07-23 | 2011-07-26 | 0d? | 130d | 0d |
| 672 | 1.2.15.2 | Brick Work | 7d | 2012-04-27 | 2012-05-04 | 671 | 2011-07-26 | 2011-08-02 | 0d? | 130d | 0d |
| 673 | 1.2.15.3 | Plaster | 5d | 2012-05-05 | 2012-05-09 | 672 | 2011-08-02 | 2011-08-09 | 0d? | 130d | 0d |
| 674 | 1.2.15.4 | **Toilet Area** | 16d | 2012-05-18 | 2012-06-02 |  | 2011-08-09 | 2011-08-20 | 0d? | 150d |  |
| 675 | 1.2.15.4.1 | Water Proofing Works | 3d | 2012-05-18 | 2012-05-20 | 812 | 2011-08-12 | 2011-08-13 | 0d? | 150d | 0d |
| 676 | 1.2.15.4.2 | Tile Works/ Marble Top | 10d | 2012-05-21 | 2012-05-30 | 675 | 2011-08-13 | 2011-08-16 | 0d? | 150d | 0d |
| 677 | 1.2.15.4.3 | Door/ Louver Install | 3d | 2012-05-31 | 2012-06-02 | 676 | 2011-08-16 | 2011-08-19 | 0d? | 150d | 0d |
| 678 | 1.2.15.5 | False Ceiling Works | 15d | 2012-05-25 | 2012-06-08 | 679, 812, 876, 954, 1019 | 2011-08-25 | 2011-09-17 | 0d? | 147d |  |
| 679 | 1.2.15.6 | Sone/Wood/Glazing in Wall | 14d | 2012-05-10 | 2012-05-24 | 673 | 2011-08-03 | 2011-08-18 | 0d? | 130d | 0d |
| 680 | 1.2.15.7 | Stair/Other Railing | 15d | 2012-05-10 | 2012-05-25 | 673 | 2011-08-02 | 2011-08-18 | 0d? | 161d |  |
| 681 | 1.2.15.8 | Granite Flooring | 10d | 2012-05-25 | 2012-06-03 | 679 | 2011-08-19 | 2011-09-06 | 0d? | 130d | 0d |
| 682 | 1.2.15.9 | Resin Floor | 15d | 2012-06-04 | 2012-06-18 | 681 | 2011-08-17 | 2011-09-09 | 0d? | 130d | 0d |
| 683 | 1.2.15.10 | Fire Door Installation | 7d | 2012-05-10 | 2012-05-16 | 673 | 2011-09-05 | 2011-09-12 | 0d? | 169d |  |
| 684 | 1.2.15.11 | Painting | 15d | 2012-06-11 | 2012-06-25 | 673FS+21d, 682FF+7d | 2011-09-07 | 2011-09-22 | 0d? | 130d |  |

| ID | WBS | Task | Duration | Start | Finish | Predecessors | Baseline start | Baseline finish | Baseline duration | Total slack | Free slack |
| --- | --- | --- | --- | --- | --- | --- | --- | --- | --- | --- | --- |
| 685 | 1.2.16 | **11th Floor** | 63d | 2012-05-13 | 2012-07-16 |  | 2011-07-23 | 2011-09-22 | 53d | 110d |  |
| 686 | 1.2.16.1 | De-shuttering Roof Slab | 5d | 2012-05-13 | 2012-05-18 | 386FS+28d | 2011-07-23 | 2011-07-26 | 0d? | 110d | 0d |
| 687 | 1.2.16.2 | Brick Work | 7d | 2012-05-19 | 2012-05-25 | 686 | 2011-07-26 | 2011-08-02 | 0d? | 110d | 0d |
| 688 | 1.2.16.3 | Plaster | 5d | 2012-05-26 | 2012-05-30 | 687 | 2011-08-02 | 2011-08-09 | 0d? | 110d | 0d |
| 689 | 1.2.16.4 | **Toilet Area** | 16d | 2012-06-07 | 2012-06-22 |  | 2011-08-09 | 2011-08-20 | 0d? | 130d |  |
| 690 | 1.2.16.4.1 | Water Proofing Works | 3d | 2012-06-07 | 2012-06-09 | 815 | 2011-08-12 | 2011-08-13 | 0d? | 130d | 0d |
| 691 | 1.2.16.4.2 | Tile Works/ Marble Top | 10d | 2012-06-10 | 2012-06-19 | 690 | 2011-08-13 | 2011-08-16 | 0d? | 130d | 0d |
| 692 | 1.2.16.4.3 | Door/ Louver Install | 3d | 2012-06-20 | 2012-06-22 | 691 | 2011-08-16 | 2011-08-19 | 0d? | 130d | 0d |
| 693 | 1.2.16.5 | False Ceiling Works | 15d | 2012-06-14 | 2012-06-28 | 694, 815, 879, 957, 1022 | 2011-08-25 | 2011-09-17 | 0d? | 127d |  |
| 694 | 1.2.16.6 | Sone/Wood/Glazing in Wall | 14d | 2012-05-31 | 2012-06-13 | 688 | 2011-08-03 | 2011-08-18 | 0d? | 110d | 0d |
| 695 | 1.2.16.7 | Stair/Other Railing | 15d | 2012-05-31 | 2012-06-14 | 688 | 2011-08-02 | 2011-08-18 | 0d? | 141d |  |
| 696 | 1.2.16.8 | Granite Flooring | 10d | 2012-06-14 | 2012-06-23 | 694 | 2011-08-19 | 2011-09-06 | 0d? | 110d | 0d |
| 697 | 1.2.16.9 | Resin Floor | 15d | 2012-06-24 | 2012-07-09 | 696 | 2011-08-17 | 2011-09-09 | 0d? | 110d | 0d |
| 698 | 1.2.16.10 | Fire Door Installation | 7d | 2012-05-31 | 2012-06-06 | 688 | 2011-09-05 | 2011-09-12 | 0d? | 149d |  |
| 699 | 1.2.16.11 | Painting | 15d | 2012-07-01 | 2012-07-16 | 688FS+21d, 697FF+7d | 2011-09-07 | 2011-09-22 | 0d? | 110d |  |
| 700 | 1.2.17 | **12th Floor** | 63d | 2012-06-03 | 2012-08-05 |  | 2011-07-23 | 2011-09-22 | 53d | 90d |  |
| 701 | 1.2.17.1 | De-shuttering Roof Slab | 5d | 2012-06-03 | 2012-06-07 | 418FS+28d | 2011-07-23 | 2011-07-26 | 0d? | 90d | 0d |
| 702 | 1.2.17.2 | Brick Work | 7d | 2012-06-08 | 2012-06-14 | 701 | 2011-07-26 | 2011-08-02 | 0d? | 90d | 0d |
| 703 | 1.2.17.3 | Plaster | 5d | 2012-06-15 | 2012-06-19 | 702 | 2011-08-02 | 2011-08-09 | 0d? | 90d | 0d |
| 704 | 1.2.17.4 | **Toilet Area** | 16d | 2012-06-27 | 2012-07-13 |  | 2011-08-09 | 2011-08-20 | 0d? | 110d |  |
| 705 | 1.2.17.4.1 | Water Proofing Works | 3d | 2012-06-27 | 2012-06-29 | 818 | 2011-08-12 | 2011-08-13 | 0d? | 110d | 0d |
| 706 | 1.2.17.4.2 | Tile Works/ Marble Top | 10d | 2012-06-30 | 2012-07-10 | 705 | 2011-08-13 | 2011-08-16 | 0d? | 110d | 0d |
| 707 | 1.2.17.4.3 | Door/ Louver Install | 3d | 2012-07-11 | 2012-07-13 | 706 | 2011-08-16 | 2011-08-19 | 0d? | 110d | 0d |
| 708 | 1.2.17.5 | False Ceiling Works | 15d | 2012-07-04 | 2012-07-19 | 709 | 2011-08-25 | 2011-09-17 | 0d? | 107d |  |
| 709 | 1.2.17.6 | Sone/Wood/Glazing in Wall | 14d | 2012-06-20 | 2012-07-03 | 703 | 2011-08-03 | 2011-08-18 | 0d? | 90d | 0d |
| 710 | 1.2.17.7 | Stair/Other Railing | 15d | 2012-06-20 | 2012-07-04 | 703 | 2011-08-02 | 2011-08-18 | 0d? | 121d |  |
| 711 | 1.2.17.8 | Granite Flooring | 10d | 2012-07-04 | 2012-07-14 | 709 | 2011-08-19 | 2011-09-06 | 0d? | 90d | 0d |
| 712 | 1.2.17.9 | Resin Floor | 15d | 2012-07-15 | 2012-07-29 | 711 | 2011-08-17 | 2011-09-09 | 0d? | 90d | 0d |
| 713 | 1.2.17.10 | Fire Door Installation | 7d | 2012-06-20 | 2012-06-26 | 703 | 2011-09-05 | 2011-09-12 | 0d? | 129d |  |
| 714 | 1.2.17.11 | Painting | 15d | 2012-07-22 | 2012-08-05 | 703FS+21d, 712FF+7d | 2011-09-07 | 2011-09-22 | 0d? | 90d |  |

| ID | WBS | Task | Duration | Start | Finish | Predecessors | Baseline start | Baseline finish | Baseline duration | Total slack | Free slack |
| --- | --- | --- | --- | --- | --- | --- | --- | --- | --- | --- | --- |
| 715 | 1.2.18 | **13th Floor** | 63d | 2012-06-23 | 2012-09-01 |  | 2011-07-23 | 2011-09-22 | 53d | 70d |  |
| 716 | 1.2.18.1 | De-shuttering Roof Slab | 5d | 2012-06-23 | 2012-06-27 | 450FS+28d | 2011-07-23 | 2011-07-26 | 0d? | 70d | 0d |
| 717 | 1.2.18.2 | Brick Work | 7d | 2012-06-28 | 2012-07-04 | 716 | 2011-07-26 | 2011-08-02 | 0d? | 70d | 0d |
| 718 | 1.2.18.3 | Plaster | 5d | 2012-07-05 | 2012-07-10 | 717 | 2011-08-02 | 2011-08-09 | 0d? | 70d | 0d |
| 719 | 1.2.18.4 | **Toilet Area** | 16d | 2012-07-18 | 2012-08-02 |  | 2011-08-09 | 2011-08-20 | 0d? | 90d |  |
| 720 | 1.2.18.4.1 | Water Proofing Works | 3d | 2012-07-18 | 2012-07-20 | 821 | 2011-08-12 | 2011-08-13 | 0d? | 90d | 0d |
| 721 | 1.2.18.4.2 | Tile Works/ Marble Top | 10d | 2012-07-21 | 2012-07-30 | 720 | 2011-08-13 | 2011-08-16 | 0d? | 90d | 0d |
| 722 | 1.2.18.4.3 | Door/ Louver Install | 3d | 2012-07-31 | 2012-08-02 | 721 | 2011-08-16 | 2011-08-19 | 0d? | 90d | 0d |
| 723 | 1.2.18.5 | False Ceiling Works | 15d | 2012-07-25 | 2012-08-08 | 724 | 2011-08-25 | 2011-09-17 | 0d? | 87d |  |
| 724 | 1.2.18.6 | Sone/Wood/Glazing in Wall | 14d | 2012-07-11 | 2012-07-24 | 718 | 2011-08-03 | 2011-08-18 | 0d? | 70d | 0d |
| 725 | 1.2.18.7 | Stair/Other Railing | 15d | 2012-07-11 | 2012-07-25 | 718 | 2011-08-02 | 2011-08-18 | 0d? | 101d |  |
| 726 | 1.2.18.8 | Granite Flooring | 10d | 2012-07-25 | 2012-08-03 | 724 | 2011-08-19 | 2011-09-06 | 0d? | 70d | 0d |
| 727 | 1.2.18.9 | Resin Floor | 15d | 2012-08-04 | 2012-08-25 | 726 | 2011-08-17 | 2011-09-09 | 0d? | 70d | 0d |
| 728 | 1.2.18.10 | Fire Door Installation | 7d | 2012-07-11 | 2012-07-17 | 718 | 2011-09-05 | 2011-09-12 | 0d? | 109d |  |
| 729 | 1.2.18.11 | Painting | 15d | 2012-08-11 | 2012-09-01 | 718FS+21d, 727FF+7d | 2011-09-07 | 2011-09-22 | 0d? | 70d |  |
| 730 | 1.2.19 | **Top Floor** | 72d | 2012-07-06 | 2012-09-23 |  | 2011-07-23 | 2011-09-22 | 53d | 20d |  |
| 731 | 1.2.19.1 | De-shuttering Roof Slab | 5d | 2012-07-06 | 2012-07-11 | 474FS+21d | 2011-07-23 | 2011-07-26 | 0d? | 20d | 0d |
| 732 | 1.2.19.2 | Brick Work | 7d | 2012-07-12 | 2012-07-18 | 731 | 2011-07-26 | 2011-08-02 | 0d? | 20d | 0d |
| 733 | 1.2.19.3 | Plaster | 5d | 2012-07-21 | 2012-07-25 | 732FF+7d | 2011-08-02 | 2011-08-09 | 0d? | 20d | 0d |
| 734 | 1.2.19.4 | **Toilet Area** | 16d | 2012-08-05 | 2012-08-27 |  | 2011-08-09 | 2011-08-20 | 0d? | 60d |  |
| 735 | 1.2.19.4.1 | Water Proofing Works | 3d | 2012-08-05 | 2012-08-07 | 824 | 2011-08-12 | 2011-08-13 | 0d? | 60d | 0d |
| 736 | 1.2.19.4.2 | Tile Works/ Marble Top | 10d | 2012-08-08 | 2012-08-19 | 735 | 2011-08-13 | 2011-08-16 | 0d? | 60d | 0d |
| 737 | 1.2.19.4.3 | Door/ Louver Install | 3d | 2012-08-25 | 2012-08-27 | 736 | 2011-08-16 | 2011-08-19 | 0d? | 60d | 0d |
| 738 | 1.2.19.5 | False Ceiling Works | 15d | 2012-08-09 | 2012-08-30 | 739 | 2011-08-25 | 2011-09-17 | 0d? | 72d |  |
| 739 | 1.2.19.6 | Sone/Wood/Glazing in Wall | 14d | 2012-07-26 | 2012-08-08 | 733 | 2011-08-03 | 2011-08-18 | 0d? | 20d | 0d |
| 740 | 1.2.19.7 | Stair/Other Railing | 15d | 2012-07-26 | 2012-08-09 | 733 | 2011-08-02 | 2011-08-18 | 0d? | 86d |  |
| 741 | 1.2.19.8 | Granite Flooring | 10d | 2012-08-09 | 2012-08-25 | 739 | 2011-08-19 | 2011-09-06 | 0d? | 77d |  |
| 742 | 1.2.19.9 | Swimming Pool | 60d | 2012-07-12 | 2012-09-16 | 731 | 2011-08-17 | 2011-09-09 | 0d? | 48d | 0d |
| 743 | 1.2.19.10 | Fire Door Installation | 7d | 2012-07-26 | 2012-08-01 | 733 | 2011-09-05 | 2011-09-12 | 0d? | 94d |  |
| 744 | 1.2.19.11 | Painting | 15d | 2012-09-09 | 2012-09-23 | 733FS+21d, 742FF+7d | 2011-09-07 | 2011-09-22 | 0d? | 48d |  |

| ID | WBS | Task | Duration | Start | Finish | Predecessors | Total slack | Free slack |
| --- | --- | --- | --- | --- | --- | --- | --- | --- |
| 745 | 1.3 | **Out-side Work** | 441d | 2011-07-28 | 2012-11-17 |  | 0d |  |
| 746 | 1.3.1 | **Louver Work** | 441d | 2011-07-28 | 2012-11-17 |  | 0d |  |
| 747 | 1.3.1.1 | Contractor Selection | 90d | 2011-07-28 | 2011-11-02 | 4SS | 351d |  |
| 748 | 1.3.1.2 | Material Delivery | 90d | 2012-04-04 | 2012-07-06 | 749SF | 120d |  |
| 749 | 1.3.1.3 | Installation | 120d | 2012-07-06 | 2012-11-17 | 474FS+21d | 0d |  |
| 750 | 1.3.2 | **Shading Canopy** | 441d | 2011-07-28 | 2012-11-17 |  | 0d |  |
| 751 | 1.3.2.1 | Contractor Selection | 90d | 2011-07-28 | 2011-11-02 | 4SS | 351d |  |
| 752 | 1.3.2.2 | Material Delivery | 90d | 2012-04-04 | 2012-07-06 | 753SF | 120d |  |
| 753 | 1.3.2.3 | Installation | 120d | 2012-07-06 | 2012-11-17 | 474FS+21d | 0d |  |
| 754 | 1.3.3 | **Cladding Work** | 441d | 2011-07-28 | 2012-11-17 |  | 0d |  |
| 755 | 1.3.3.1 | Contractor Selection | 90d | 2011-07-28 | 2011-11-02 | 4SS | 351d |  |
| 756 | 1.3.3.2 | Material Delivery | 90d | 2012-04-04 | 2012-07-06 | 757SF | 120d |  |
| 757 | 1.3.3.3 | Installation | 120d | 2012-07-06 | 2012-11-17 | 474FS+21d | 0d |  |
| 758 | 1.3.4 | **Roof Protection** | 351d | 2011-07-28 | 2012-08-05 |  | 90d |  |
| 759 | 1.3.4.1 | Contractor Selection | 90d | 2011-07-28 | 2011-11-02 | 4SS | 351d |  |
| 760 | 1.3.4.2 | Material Delivery | 90d | 2012-04-04 | 2012-07-06 | 761SF | 120d |  |
| 761 | 1.3.4.3 | Installation | 30d | 2012-07-06 | 2012-08-05 | 474FS+21d | 90d | 0d |
| 762 | 1.4 | **Surrounding Work** | 150d | 2012-06-06 | 2012-11-17 |  | 0d |  |
| 763 | 1.4.1 | Underground Pipe Work | 60d | 2012-06-06 | 2012-08-06 | 764SF | 90d |  |
| 764 | 1.4.2 | Landscaping | 90d | 2012-08-06 | 2012-11-17 | 745FF | 0d |  |
| 765 | 1.5 | **MEP (Mechanical Electrical and Plumbing ) Work** | 441d | 2011-07-28 | 2012-11-17 |  | 0d |  |
| 766 | 1.5.1 | **Selection of Contractor** | 45d | 2011-08-12 | 2011-10-03 |  | 381d |  |
| 767 | 1.5.1.1 | Sanitary & Plumbing | 45d | 2011-08-12 | 2011-10-03 | 779SF | 381d |  |
| 768 | 1.5.1.2 | Fire Protection & Detection | 45d | 2011-08-12 | 2011-10-03 | 843SF | 381d |  |
| 769 | 1.5.1.3 | Electrical Work | 45d | 2011-08-12 | 2011-10-03 | 905SF | 381d |  |
| 770 | 1.5.1.4 | A/c Work | 45d | 2011-08-12 | 2011-10-03 | 986SF | 381d |  |

| ID | WBS | Task | Duration | Start | Finish | Predecessors | Total slack | Free slack |
| --- | --- | --- | --- | --- | --- | --- | --- | --- |
| 771 | 1.5.2 | **Sanitary & Plumbing Work** | 320d | 2011-10-03 | 2012-09-10 |  | 61d |  |
| 772 | 1.5.2.1 | **Basement 3** | 13d | 2011-10-21 | 2011-11-02 |  | 310d |  |
| 773 | 1.5.2.1.1 | Water & Sewerage Pipe Line | 10d | 2011-10-21 | 2011-10-30 | 776 | 310d | 0d |
| 774 | 1.5.2.1.2 | Sanitary Fittings & Fixtures | 3d | 2011-10-31 | 2011-11-02 | 773 | 351d |  |
| 775 | 1.5.2.2 | **Basement 2** | 10d | 2011-10-14 | 2011-10-23 |  | 310d |  |
| 776 | 1.5.2.2.1 | Water & Sewerage Pipe Line | 7d | 2011-10-14 | 2011-10-20 | 779 | 310d | 0d |
| 777 | 1.5.2.2.2 | Sanitary Fittings & Fixtures | 3d | 2011-10-21 | 2011-10-23 | 776 | 361d |  |
| 778 | 1.5.2.3 | **Basement 1** | 32d | 2011-10-03 | 2011-11-04 |  | 310d |  |
| 779 | 1.5.2.3.1 | Water & Sewerage Pipe Line | 10d | 2011-10-03 | 2011-10-13 | 503 | 310d | 0d |
| 780 | 1.5.2.3.2 | Sanitary Fittings & Fixtures | 3d | 2011-11-02 | 2011-11-04 | 508 | 349d |  |
| 781 | 1.5.2.4 | **Ground Floor** | 31d | 2011-11-12 | 2011-12-13 |  | 308d |  |
| 782 | 1.5.2.4.1 | Water & Sewerage Pipe Line | 10d | 2011-11-12 | 2011-11-21 | 522 | 308d | 0d |
| 783 | 1.5.2.4.2 | Sanitary Fittings & Fixtures | 3d | 2011-12-11 | 2011-12-13 | 526 | 317d |  |
| 784 | 1.5.2.5 | **1st Floor** | 26d | 2011-10-29 | 2011-11-29 |  | 330d |  |
| 785 | 1.5.2.5.1 | Water & Sewerage Pipe Line | 7d | 2011-10-29 | 2011-11-04 | 538 | 330d | 0d |
| 786 | 1.5.2.5.2 | Sanitary Fittings & Fixtures | 3d | 2011-11-27 | 2011-11-29 | 542 | 330d |  |
| 787 | 1.5.2.6 | **2nd Floor** | 26d | 2011-11-24 | 2011-12-21 |  | 310d |  |
| 788 | 1.5.2.6.1 | Water & Sewerage Pipe Line | 7d | 2011-11-24 | 2011-11-30 | 553 | 310d | 0d |
| 789 | 1.5.2.6.2 | Sanitary Fittings & Fixtures | 3d | 2011-12-19 | 2011-12-21 | 557 | 310d |  |
| 790 | 1.5.2.7 | **3rd Floor** | 26d | 2011-12-15 | 2012-01-11 |  | 290d |  |
| 791 | 1.5.2.7.1 | Water & Sewerage Pipe Line | 7d | 2011-12-15 | 2011-12-22 | 568 | 290d | 0d |
| 792 | 1.5.2.7.2 | Sanitary Fittings & Fixtures | 3d | 2012-01-09 | 2012-01-11 | 572 | 290d |  |
| 793 | 1.5.2.8 | **4th Floor** | 26d | 2012-01-06 | 2012-01-31 |  | 270d |  |
| 794 | 1.5.2.8.1 | Water & Sewerage Pipe Line | 7d | 2012-01-06 | 2012-01-12 | 583 | 270d | 0d |
| 795 | 1.5.2.8.2 | Sanitary Fittings & Fixtures | 3d | 2012-01-29 | 2012-01-31 | 587 | 270d |  |

| ID | WBS | Task | Duration | Start | Finish | Predecessors | Total slack | Free slack |
| --- | --- | --- | --- | --- | --- | --- | --- | --- |
| 796 | 1.5.2.9 | **5th Floor** | 26d | 2012-01-26 | 2012-02-22 |  | 250d |  |
| 797 | 1.5.2.9.1 | Water & Sewerage Pipe Line | 7d | 2012-01-26 | 2012-02-01 | 598 | 250d | 0d |
| 798 | 1.5.2.9.2 | Sanitary Fittings & Fixtures | 3d | 2012-02-19 | 2012-02-22 | 602 | 250d |  |
| 799 | 1.5.2.10 | **6th Floor** | 26d | 2012-02-16 | 2012-03-13 |  | 230d |  |
| 800 | 1.5.2.10.1 | Water & Sewerage Pipe Line | 7d | 2012-02-16 | 2012-02-23 | 613 | 230d | 0d |
| 801 | 1.5.2.10.2 | Sanitary Fittings & Fixtures | 3d | 2012-03-11 | 2012-03-13 | 617 | 230d |  |
| 802 | 1.5.2.11 | **7th Floor** | 26d | 2012-03-08 | 2012-04-03 |  | 210d |  |
| 803 | 1.5.2.11.1 | Water & Sewerage Pipe Line | 7d | 2012-03-08 | 2012-03-14 | 628 | 210d | 0d |
| 804 | 1.5.2.11.2 | Sanitary Fittings & Fixtures | 3d | 2012-04-01 | 2012-04-03 | 632 | 210d |  |
| 805 | 1.5.2.12 | **8th Floor** | 26d | 2012-03-29 | 2012-04-24 |  | 190d |  |
| 806 | 1.5.2.12.1 | Water & Sewerage Pipe Line | 7d | 2012-03-29 | 2012-04-04 | 643 | 190d | 0d |
| 807 | 1.5.2.12.2 | Sanitary Fittings & Fixtures | 3d | 2012-04-22 | 2012-04-24 | 647 | 190d |  |
| 808 | 1.5.2.13 | **9th Floor** | 26d | 2012-04-19 | 2012-05-15 |  | 170d |  |
| 809 | 1.5.2.13.1 | Water & Sewerage Pipe Line | 7d | 2012-04-19 | 2012-04-25 | 658 | 170d | 0d |
| 810 | 1.5.2.13.2 | Sanitary Fittings & Fixtures | 3d | 2012-05-13 | 2012-05-15 | 662 | 170d |  |
| 811 | 1.5.2.14 | **10th Floor** | 26d | 2012-05-10 | 2012-06-05 |  | 150d |  |
| 812 | 1.5.2.14.1 | Water & Sewerage Pipe Line | 7d | 2012-05-10 | 2012-05-16 | 673 | 150d | 0d |
| 813 | 1.5.2.14.2 | Sanitary Fittings & Fixtures | 3d | 2012-06-03 | 2012-06-05 | 677 | 150d |  |
| 814 | 1.5.2.15 | **11th Floor** | 26d | 2012-05-31 | 2012-06-25 |  | 130d |  |
| 815 | 1.5.2.15.1 | Water & Sewerage Pipe Line | 7d | 2012-05-31 | 2012-06-06 | 688 | 130d | 0d |
| 816 | 1.5.2.15.2 | Sanitary Fittings & Fixtures | 3d | 2012-06-23 | 2012-06-25 | 692 | 130d |  |
| 817 | 1.5.2.16 | **12th Floor** | 26d | 2012-06-20 | 2012-07-16 |  | 110d |  |
| 818 | 1.5.2.16.1 | Water & Sewerage Pipe Line | 7d | 2012-06-20 | 2012-06-26 | 703 | 110d | 0d |
| 819 | 1.5.2.16.2 | Sanitary Fittings & Fixtures | 3d | 2012-07-14 | 2012-07-16 | 707 | 110d |  |

| ID | WBS | Task | Duration | Start | Finish | Predecessors | Total slack | Free slack |
| --- | --- | --- | --- | --- | --- | --- | --- | --- |
| 820 | 1.5.2.17 | **13th Floor** | 26d | 2012-07-11 | 2012-08-05 |  | 90d |  |
| 821 | 1.5.2.17.1 | Water & Sewerage Pipe Line | 7d | 2012-07-11 | 2012-07-17 | 718 | 90d | 0d |
| 822 | 1.5.2.17.2 | Sanitary Fittings & Fixtures | 3d | 2012-08-03 | 2012-08-05 | 722 | 90d |  |
| 823 | 1.5.2.18 | **Top Floor** | 33d | 2012-07-26 | 2012-09-03 |  | 60d |  |
| 824 | 1.5.2.18.1 | Water & Sewerage Pipe Line | 10d | 2012-07-26 | 2012-08-04 | 733 | 60d | 0d |
| 825 | 1.5.2.18.2 | Sanitary Fittings & Fixtures | 7d | 2012-08-28 | 2012-09-03 | 737 | 60d | 0d |
| 826 | 1.5.2.19 | Pressure Test | 7d | 2012-09-04 | 2012-09-10 | 825 | 60d | 0d |
| 827 | 1.5.3 | **Elevator/Lift** | 370d | 2011-08-19 | 2012-09-21 |  | 50d |  |
| 828 | 1.5.3.1 | Vendor Selection and Price Negotiation | 90d | 2011-08-19 | 2011-11-30 | 829SF | 330d |  |
| 829 | 1.5.3.2 | LC Open | 20d | 2011-11-30 | 2011-12-22 | 830SF | 310d | 0d |
| 830 | 1.5.3.3 | Manufacturing | 145d | 2011-12-22 | 2012-05-22 | 831SF | 165d | 0d |
| 831 | 1.5.3.4 | Shipment | 30d | 2012-05-22 | 2012-06-21 | 832SF | 135d | 0d |
| 832 | 1.5.3.5 | Clearance from Port | 15d | 2012-06-21 | 2012-07-06 | 833SF | 120d | 0d |
| 833 | 1.5.3.6 | Installation | 60d | 2012-07-06 | 2012-09-11 | 474FS+21d | 50d | 0d |
| 834 | 1.5.3.7 | Comissioning | 10d | 2012-09-12 | 2012-09-21 | 833 | 50d |  |
| 835 | 1.5.4 | **Fire Protection System** | 361d | 2011-10-03 | 2012-10-22 |  | 20d |  |
| 836 | 1.5.4.1 | **Basement -3** | 17d | 2011-10-15 | 2011-10-31 |  | 316d |  |
| 837 | 1.5.4.1.1 | Fire Hydrnt/ Sprinkler Pipe Line | 10d | 2011-10-15 | 2011-10-24 | 487 | 316d | 0d |
| 838 | 1.5.4.1.2 | Fire Hose Cabinate Fixing | 7d | 2011-10-25 | 2011-10-31 | 837 | 353d |  |
| 839 | 1.5.4.2 | **Basement -2** | 14d | 2011-10-05 | 2011-10-19 |  | 328d |  |
| 840 | 1.5.4.2.1 | Fire Hydrnt/ Sprinkler Pipe Line | 7d | 2011-10-05 | 2011-10-12 | 495 | 328d | 0d |
| 841 | 1.5.4.2.2 | Fire Hose Cabinate Fixing | 7d | 2011-10-13 | 2011-10-19 | 840 | 365d |  |
| 842 | 1.5.4.3 | **Basement -1** | 14d | 2011-10-03 | 2011-10-17 |  | 330d |  |
| 843 | 1.5.4.3.1 | Fire Hydrnt/ Sprinkler Pipe Line | 7d | 2011-10-03 | 2011-10-10 | 503 | 330d | 0d |
| 844 | 1.5.4.3.2 | Fire Hose Cabinate Fixing | 7d | 2011-10-11 | 2011-10-17 | 843 | 367d |  |

| ID | WBS | Task | Duration | Start | Finish | Predecessors | Total slack | Free slack |
| --- | --- | --- | --- | --- | --- | --- | --- | --- |
| 845 | 1.5.4.4 | **Ground Floor** | 37d | 2011-11-12 | 2011-12-20 |  | 311d |  |
| 846 | 1.5.4.4.1 | Fire Hydrnt/ Sprinkler Pipe Line | 7d | 2011-11-12 | 2011-11-18 | 522 | 311d | 23d |
| 847 | 1.5.4.4.2 | Fire Hose Cabinate Fixing | 7d | 2011-12-13 | 2011-12-20 | 529 | 311d |  |
| 848 | 1.5.4.5 | **1st Floor** | 21d | 2011-10-29 | 2011-11-24 |  | 334d |  |
| 849 | 1.5.4.5.1 | Fire Hydrnt/ Sprinkler Pipe Line | 7d | 2011-10-29 | 2011-11-04 | 538 | 334d | 7d |
| 850 | 1.5.4.5.2 | Fire Hose Cabinate Fixing | 7d | 2011-11-18 | 2011-11-24 | 544 | 335d |  |
| 851 | 1.5.4.6 | **2nd Floor** | 21d | 2011-11-24 | 2011-12-15 |  | 315d |  |
| 852 | 1.5.4.6.1 | Fire Hydrnt/ Sprinkler Pipe Line | 7d | 2011-11-24 | 2011-11-30 | 553 | 329d |  |
| 853 | 1.5.4.6.2 | Fire Hose Cabinate Fixing | 7d | 2011-12-09 | 2011-12-15 | 559 | 315d |  |
| 854 | 1.5.4.7 | **3rd Floor** | 21d | 2011-12-15 | 2012-01-06 |  | 294d |  |
| 855 | 1.5.4.7.1 | Fire Hydrnt/ Sprinkler Pipe Line | 7d | 2011-12-15 | 2011-12-22 | 568 | 294d | 7d |
| 856 | 1.5.4.7.2 | Fire Hose Cabinate Fixing | 7d | 2011-12-31 | 2012-01-06 | 574 | 295d |  |
| 857 | 1.5.4.8 | **4th Floor** | 21d | 2012-01-06 | 2012-01-26 |  | 274d |  |
| 858 | 1.5.4.8.1 | Fire Hydrnt/ Sprinkler Pipe Line | 7d | 2012-01-06 | 2012-01-12 | 583 | 274d | 7d |
| 859 | 1.5.4.8.2 | Fire Hose Cabinate Fixing | 7d | 2012-01-20 | 2012-01-26 | 589 | 275d |  |
| 860 | 1.5.4.9 | **5th Floor** | 21d | 2012-01-26 | 2012-02-16 |  | 254d |  |
| 861 | 1.5.4.9.1 | Fire Hydrnt/ Sprinkler Pipe Line | 7d | 2012-01-26 | 2012-02-01 | 598 | 254d | 7d |
| 862 | 1.5.4.9.2 | Fire Hose Cabinate Fixing | 7d | 2012-02-10 | 2012-02-16 | 604 | 255d |  |
| 863 | 1.5.4.10 | **6th Floor** | 21d | 2012-02-16 | 2012-03-08 |  | 234d |  |
| 864 | 1.5.4.10.1 | Fire Hydrnt/ Sprinkler Pipe Line | 7d | 2012-02-16 | 2012-02-23 | 613 | 234d | 7d |
| 865 | 1.5.4.10.2 | Fire Hose Cabinate Fixing | 7d | 2012-03-02 | 2012-03-08 | 619 | 235d |  |
| 866 | 1.5.4.11 | **7th Floor** | 21d | 2012-03-08 | 2012-03-29 |  | 214d |  |
| 867 | 1.5.4.11.1 | Fire Hydrnt/ Sprinkler Pipe Line | 7d | 2012-03-08 | 2012-03-14 | 628 | 214d | 7d |
| 868 | 1.5.4.11.2 | Fire Hose Cabinate Fixing | 7d | 2012-03-23 | 2012-03-29 | 634 | 215d |  |

| ID | WBS | Task | Duration | Start | Finish | Predecessors | Total slack | Free slack |
| --- | --- | --- | --- | --- | --- | --- | --- | --- |
| 869 | 1.5.4.12 | **8th Floor** | 21d | 2012-03-29 | 2012-04-19 |  | 194d |  |
| 870 | 1.5.4.12.1 | Fire Hydrnt/ Sprinkler Pipe Line | 7d | 2012-03-29 | 2012-04-04 | 643 | 194d | 7d |
| 871 | 1.5.4.12.2 | Fire Hose Cabinate Fixing | 7d | 2012-04-12 | 2012-04-19 | 649 | 195d |  |
| 872 | 1.5.4.13 | **9th Floor** | 21d | 2012-04-19 | 2012-05-10 |  | 174d |  |
| 873 | 1.5.4.13.1 | Fire Hydrnt/ Sprinkler Pipe Line | 7d | 2012-04-19 | 2012-04-25 | 658 | 174d | 7d |
| 874 | 1.5.4.13.2 | Fire Hose Cabinate Fixing | 7d | 2012-05-04 | 2012-05-10 | 664 | 175d |  |
| 875 | 1.5.4.14 | **10th Floor** | 21d | 2012-05-10 | 2012-05-31 |  | 154d |  |
| 876 | 1.5.4.14.1 | Fire Hydrnt/ Sprinkler Pipe Line | 7d | 2012-05-10 | 2012-05-16 | 673 | 154d | 7d |
| 877 | 1.5.4.14.2 | Fire Hose Cabinate Fixing | 7d | 2012-05-25 | 2012-05-31 | 679 | 155d |  |
| 878 | 1.5.4.15 | **11th Floor** | 21d | 2012-05-31 | 2012-06-20 |  | 134d |  |
| 879 | 1.5.4.15.1 | Fire Hydrnt/ Sprinkler Pipe Line | 7d | 2012-05-31 | 2012-06-06 | 688 | 134d | 7d |
| 880 | 1.5.4.15.2 | Fire Hose Cabinate Fixing | 7d | 2012-06-14 | 2012-06-20 | 694 | 135d |  |
| 881 | 1.5.4.16 | **12th Floor** | 21d | 2012-06-20 | 2012-07-11 |  | 115d |  |
| 882 | 1.5.4.16.1 | Fire Hydrnt/ Sprinkler Pipe Line | 7d | 2012-06-20 | 2012-06-26 | 703 | 129d |  |
| 883 | 1.5.4.16.2 | Fire Hose Cabinate Fixing | 7d | 2012-07-04 | 2012-07-11 | 709 | 115d |  |
| 884 | 1.5.4.17 | **13th Floor** | 21d | 2012-07-11 | 2012-07-31 |  | 95d |  |
| 885 | 1.5.4.17.1 | Fire Hydrnt/ Sprinkler Pipe Line | 7d | 2012-07-11 | 2012-07-17 | 718 | 109d |  |
| 886 | 1.5.4.17.2 | Fire Hose Cabinate Fixing | 7d | 2012-07-25 | 2012-07-31 | 724 | 95d |  |
| 887 | 1.5.4.18 | **Top Floor** | 21d | 2012-07-26 | 2012-08-16 |  | 34d |  |
| 888 | 1.5.4.18.1 | Fire Hydrnt/ Sprinkler Pipe Line | 15d | 2012-07-26 | 2012-08-09 | 733 | 86d |  |
| 889 | 1.5.4.18.2 | Fire Hose Cabinate Fixing | 7d | 2012-08-09 | 2012-08-16 | 739 | 20d | 0d |
| 890 | 1.5.4.19 | **Equipment Installation** | 60d | 2012-08-18 | 2012-10-22 |  | 20d |  |
| 891 | 1.5.4.19.1 | Pressure Test | 7d | 2012-08-18 | 2012-08-29 | 889 | 28d | 0d |
| 892 | 1.5.4.19.2 | Fire Extingusher | 30d | 2012-08-30 | 2012-09-28 | 891 | 28d | 0d |
| 893 | 1.5.4.19.3 | Heat Detector | 30d | 2012-08-30 | 2012-09-28 | 892FF | 28d | 0d |
| 894 | 1.5.4.19.4 | Smoke Detector | 30d | 2012-08-30 | 2012-09-28 | 893FF | 28d | 8d |
| 895 | 1.5.4.19.5 | Sprinkler | 45d | 2012-08-18 | 2012-10-07 | 889 | 20d | 0d |
| 896 | 1.5.4.19.6 | Comissioning | 15d | 2012-10-08 | 2012-10-22 | 895, 892, 893, 894 | 20d |  |

| ID | WBS | Task | Duration | Start | Finish | Predecessors | Total slack | Free slack |
| --- | --- | --- | --- | --- | --- | --- | --- | --- |
| 897 | 1.5.5 | **Electrical Work** | 421d | 2011-07-28 | 2012-10-22 |  | 19d | 0d |
| 898 | 1.5.5.1 | **Basement-3** | 17d | 2011-10-15 | 2011-10-31 |  | 316d |  |
| 899 | 1.5.5.1.1 | Cable Tray/ Wiring | 10d | 2011-10-15 | 2011-10-24 | 487 | 316d | 0d |
| 900 | 1.5.5.1.2 | DB/ Switch Socket Box fixing | 7d | 2011-10-25 | 2011-10-31 | 899 | 352d |  |
| 901 | 1.5.5.2 | **Basement-2** | 17d | 2011-10-05 | 2011-10-22 |  | 325d |  |
| 902 | 1.5.5.2.1 | Cable Tray/ Wiring | 10d | 2011-10-05 | 2011-10-15 | 495 | 325d | 0d |
| 903 | 1.5.5.2.2 | DB/ Switch Socket Box fixing | 7d | 2011-10-16 | 2011-10-22 | 902 | 361d |  |
| 904 | 1.5.5.3 | **Basement-1** | 265d | 2011-07-28 | 2012-05-09 |  | 165d |  |
| 905 | 1.5.5.3.1 | Cable Tray/ Wiring | 10d | 2011-10-03 | 2011-10-13 | 503 | 327d | 0d |
| 906 | 1.5.5.3.2 | DB/ Switch Socket Box fixing | 7d | 2011-10-14 | 2011-10-20 | 905 | 363d |  |
| 907 | 1.5.5.3.3 | **Generator** | 265d | 2011-07-28 | 2012-05-09 |  | 165d |  |
| 908 | 1.5.5.3.3.1 | Vendor Selection and Price Negotiation | 60d | 2011-07-28 | 2011-10-02 | 4SS | 165d | 0d |
| 909 | 1.5.5.3.3.2 | LC Open | 15d | 2011-10-03 | 2011-10-18 | 908 | 165d | 0d |
| 910 | 1.5.5.3.3.3 | Manufacturing | 45d | 2011-10-19 | 2011-12-09 | 909 | 165d | 0d |
| 911 | 1.5.5.3.3.4 | Shipment | 30d | 2011-12-10 | 2012-01-10 | 910 | 165d | 0d |
| 912 | 1.5.5.3.3.5 | Clearance from Port | 15d | 2012-01-11 | 2012-01-25 | 911 | 165d | 0d |
| 913 | 1.5.5.3.3.6 | Installation | 90d | 2012-01-26 | 2012-04-28 | 912 | 165d | 0d |
| 914 | 1.5.5.3.3.7 | Comissioning | 10d | 2012-04-29 | 2012-05-09 | 913 | 165d | 146d |
| 915 | 1.5.5.3.4 | **Sub-Station** | 205d | 2011-07-28 | 2012-03-07 |  | 225d |  |
| 916 | 1.5.5.3.4.1 | Vendor Selection and Price Negotiation | 60d | 2011-07-28 | 2011-10-02 | 4SS | 225d | 0d |
| 917 | 1.5.5.3.4.2 | LC Open | 15d | 2011-10-03 | 2011-10-18 | 916 | 225d | 0d |
| 918 | 1.5.5.3.4.3 | Manufacturing | 45d | 2011-10-19 | 2011-12-09 | 917 | 225d | 0d |
| 919 | 1.5.5.3.4.4 | Shipment | 30d | 2011-12-10 | 2012-01-10 | 918 | 225d | 0d |
| 920 | 1.5.5.3.4.5 | Clearance from Port | 15d | 2012-01-11 | 2012-01-25 | 919 | 225d | 0d |
| 921 | 1.5.5.3.4.6 | Installation | 30d | 2012-01-26 | 2012-02-26 | 920 | 225d | 0d |
| 922 | 1.5.5.3.4.7 | Comissioning | 10d | 2012-02-27 | 2012-03-07 | 921 | 225d | 206d |

| ID | WBS | Task | Duration | Start | Finish | Predecessors | Total slack | Free slack |
| --- | --- | --- | --- | --- | --- | --- | --- | --- |
| 923 | 1.5.5.4 | **Ground Floor** | 17d | 2011-11-12 | 2011-11-28 |  | 308d |  |
| 924 | 1.5.5.4.1 | Cable Tray/ Wiring | 10d | 2011-11-12 | 2011-11-21 | 522 | 308d | 0d |
| 925 | 1.5.5.4.2 | DB/ Switch Socket Box fixing | 7d | 2011-11-22 | 2011-11-28 | 924 | 330d |  |
| 926 | 1.5.5.5 | **1st Floor** | 17d | 2011-10-29 | 2011-11-20 |  | 331d |  |
| 927 | 1.5.5.5.1 | Cable Tray/ Wiring | 10d | 2011-10-29 | 2011-11-13 | 538 | 331d | 0d |
| 928 | 1.5.5.5.2 | DB/ Switch Socket Box fixing | 7d | 2011-11-14 | 2011-11-20 | 927 | 338d |  |
| 929 | 1.5.5.6 | **2nd Floor** | 17d | 2011-11-18 | 2011-12-04 |  | 317d |  |
| 930 | 1.5.5.6.1 | Cable Tray/ Wiring | 10d | 2011-11-18 | 2011-11-27 | 544 | 317d | 0d |
| 931 | 1.5.5.6.2 | DB/ Switch Socket Box fixing | 7d | 2011-11-28 | 2011-12-04 | 930 | 324d |  |
| 932 | 1.5.5.7 | **3rd Floor** | 17d | 2011-11-24 | 2011-12-11 |  | 304d |  |
| 933 | 1.5.5.7.1 | Cable Tray/ Wiring | 10d | 2011-11-24 | 2011-12-03 | 553 | 304d | 0d |
| 934 | 1.5.5.7.2 | DB/ Switch Socket Box fixing | 7d | 2011-12-04 | 2011-12-11 | 933 | 304d | 17d |
| 935 | 1.5.5.8 | **4th Floor** | 17d | 2012-01-06 | 2012-01-22 |  | 271d |  |
| 936 | 1.5.5.8.1 | Cable Tray/ Wiring | 10d | 2012-01-06 | 2012-01-15 | 583 | 271d | 0d |
| 937 | 1.5.5.8.2 | DB/ Switch Socket Box fixing | 7d | 2012-01-16 | 2012-01-22 | 936 | 278d |  |
| 938 | 1.5.5.9 | **5th Floor** | 17d | 2012-01-26 | 2012-02-12 |  | 251d |  |
| 939 | 1.5.5.9.1 | Cable Tray/ Wiring | 10d | 2012-01-26 | 2012-02-04 | 598 | 251d | 0d |
| 940 | 1.5.5.9.2 | DB/ Switch Socket Box fixing | 7d | 2012-02-05 | 2012-02-12 | 939 | 258d |  |
| 941 | 1.5.5.10 | **6th Floor** | 17d | 2012-02-16 | 2012-03-04 |  | 231d |  |
| 942 | 1.5.5.10.1 | Cable Tray/ Wiring | 10d | 2012-02-16 | 2012-02-26 | 613 | 231d | 0d |
| 943 | 1.5.5.10.2 | DB/ Switch Socket Box fixing | 7d | 2012-02-27 | 2012-03-04 | 942 | 238d |  |
| 944 | 1.5.5.11 | **7th Floor** | 17d | 2012-03-08 | 2012-03-25 |  | 211d |  |
| 945 | 1.5.5.11.1 | Cable Tray/ Wiring | 10d | 2012-03-08 | 2012-03-18 | 628 | 211d | 0d |
| 946 | 1.5.5.11.2 | DB/ Switch Socket Box fixing | 7d | 2012-03-19 | 2012-03-25 | 945 | 218d |  |

| ID | WBS | Task | Duration | Start | Finish | Predecessors | Total slack | Free slack |
| --- | --- | --- | --- | --- | --- | --- | --- | --- |
| 947 | 1.5.5.12 | **8th Floor** | 17d | 2012-03-29 | 2012-04-15 |  | 191d |  |
| 948 | 1.5.5.12.1 | Cable Tray/ Wiring | 10d | 2012-03-29 | 2012-04-07 | 643 | 191d | 0d |
| 949 | 1.5.5.12.2 | DB/ Switch Socket Box fixing | 7d | 2012-04-08 | 2012-04-15 | 948 | 198d |  |
| 950 | 1.5.5.13 | **9th Floor** | 17d | 2012-04-19 | 2012-05-06 |  | 171d |  |
| 951 | 1.5.5.13.1 | Cable Tray/ Wiring | 10d | 2012-04-19 | 2012-04-28 | 658 | 171d | 0d |
| 952 | 1.5.5.13.2 | DB/ Switch Socket Box fixing | 7d | 2012-04-29 | 2012-05-06 | 951 | 178d |  |
| 953 | 1.5.5.14 | **10th Floor** | 17d | 2012-05-10 | 2012-05-27 |  | 151d |  |
| 954 | 1.5.5.14.1 | Cable Tray/ Wiring | 10d | 2012-05-10 | 2012-05-20 | 673 | 151d | 0d |
| 955 | 1.5.5.14.2 | DB/ Switch Socket Box fixing | 7d | 2012-05-21 | 2012-05-27 | 954 | 158d |  |
| 956 | 1.5.5.15 | **11th Floor** | 17d | 2012-05-31 | 2012-06-16 |  | 131d |  |
| 957 | 1.5.5.15.1 | Cable Tray/ Wiring | 10d | 2012-05-31 | 2012-06-09 | 688 | 131d | 0d |
| 958 | 1.5.5.15.2 | DB/ Switch Socket Box fixing | 7d | 2012-06-10 | 2012-06-16 | 957 | 138d |  |
| 959 | 1.5.5.16 | **12th Floor** | 17d | 2012-06-20 | 2012-07-06 |  | 118d |  |
| 960 | 1.5.5.16.1 | Cable Tray/ Wiring | 10d | 2012-06-20 | 2012-06-29 | 703 | 118d | 0d |
| 961 | 1.5.5.16.2 | DB/ Switch Socket Box fixing | 7d | 2012-06-30 | 2012-07-06 | 960 | 118d |  |
| 962 | 1.5.5.17 | **13th Floor** | 17d | 2012-07-11 | 2012-07-27 |  | 98d |  |
| 963 | 1.5.5.17.1 | Cable Tray/ Wiring | 10d | 2012-07-11 | 2012-07-20 | 718 | 98d | 0d |
| 964 | 1.5.5.17.2 | DB/ Switch Socket Box fixing | 7d | 2012-07-21 | 2012-07-27 | 963 | 98d |  |
| 965 | 1.5.5.18 | **Top Floor** | 17d | 2012-07-26 | 2012-08-11 |  | 73d |  |
| 966 | 1.5.5.18.1 | Cable Tray/ Wiring | 10d | 2012-07-26 | 2012-08-04 | 733 | 73d | 0d |
| 967 | 1.5.5.18.2 | DB/ Switch Socket Box fixing | 7d | 2012-08-05 | 2012-08-11 | 966 | 73d | 54d |
| 968 | 1.5.5.19 | **Busbar Trunking** | 220d | 2012-03-04 | 2012-10-22 |  | 19d |  |
| 969 | 1.5.5.19.1 | Material Delivery | 120d | 2012-03-04 | 2012-07-06 | 970SF | 119d |  |
| 970 | 1.5.5.19.2 | Installation | 90d | 2012-07-06 | 2012-10-12 | 474FS+21d | 19d | 0d |
| 971 | 1.5.5.19.3 | Commissioning | 10d | 2012-10-13 | 2012-10-22 | 967, 970, 914, 922, 973 | 19d |  |

| ID | WBS | Task | Duration | Start | Finish | Predecessors | Total slack | Free slack |
| --- | --- | --- | --- | --- | --- | --- | --- | --- |
| 972 | 1.5.5.20 | **Lighting Works** | 90d | 2012-07-06 | 2012-10-12 |  | 19d |  |
| 973 | 1.5.5.20.1 | All kinds of lighting work as per Standard | 90d | 2012-07-06 | 2012-10-12 | 970FF | 19d | 0d |
| 974 | 1.5.5.21 | **Ligtening Works** | 411d | 2011-07-28 | 2012-10-12 |  | 29d |  |
| 975 | 1.5.5.21.1 | Contractor Selection | 90d | 2011-07-28 | 2011-11-02 | 4SS | 350d |  |
| 976 | 1.5.5.21.2 | Material Delivery | 90d | 2012-06-06 | 2012-09-12 | 977SF | 59d |  |
| 977 | 1.5.5.21.3 | Installation | 30d | 2012-09-12 | 2012-10-12 | 970FF | 29d | 0d |
| 978 | 1.5.6 | **A/C Work/ Air Ventilation System** | 294d | 2011-10-03 | 2012-08-08 |  | 87d |  |
| 979 | 1.5.6.1 | **Basement -3** | 14d | 2011-10-15 | 2011-10-28 |  | 319d |  |
| 980 | 1.5.6.1.1 | Ducting/ Cable Work | 7d | 2011-10-15 | 2011-10-21 | 487 | 319d | 0d |
| 981 | 1.5.6.1.2 | Installation A/C | 7d | 2011-10-22 | 2011-10-28 | 980 | 356d |  |
| 982 | 1.5.6.2 | **Basement -2** | 14d | 2011-10-05 | 2011-10-19 |  | 328d |  |
| 983 | 1.5.6.2.1 | Ducting/ Cable Work | 7d | 2011-10-05 | 2011-10-12 | 495 | 328d | 0d |
| 984 | 1.5.6.2.2 | Installation A/C | 7d | 2011-10-13 | 2011-10-19 | 983 | 365d |  |
| 985 | 1.5.6.3 | **Basement -1** | 14d | 2011-10-03 | 2011-10-17 |  | 330d |  |
| 986 | 1.5.6.3.1 | Ducting/ Cable Work | 7d | 2011-10-03 | 2011-10-10 | 503 | 330d | 0d |
| 987 | 1.5.6.3.2 | Installation A/C | 7d | 2011-10-11 | 2011-10-17 | 986 | 367d |  |
| 988 | 1.5.6.4 | **Ground Floor** | 14d | 2011-11-12 | 2011-11-25 |  | 311d |  |
| 989 | 1.5.6.4.1 | Ducting/ Cable Work | 7d | 2011-11-12 | 2011-11-18 | 522 | 311d | 0d |
| 990 | 1.5.6.4.2 | Installation A/C | 7d | 2011-11-19 | 2011-11-25 | 989 | 334d |  |
| 991 | 1.5.6.5 | **1st Floor** | 14d | 2011-10-29 | 2011-11-17 |  | 334d |  |
| 992 | 1.5.6.5.1 | Ducting/ Cable Work | 7d | 2011-10-29 | 2011-11-04 | 538 | 334d | 0d |
| 993 | 1.5.6.5.2 | Installation A/C | 7d | 2011-11-05 | 2011-11-17 | 992 | 342d |  |
| 994 | 1.5.6.6 | **2nd Floor** | 14d | 2011-11-18 | 2011-12-01 |  | 320d |  |
| 995 | 1.5.6.6.1 | Ducting/ Cable Work | 7d | 2011-11-18 | 2011-11-24 | 544 | 320d | 0d |
| 996 | 1.5.6.6.2 | Installation A/C | 7d | 2011-11-25 | 2011-12-01 | 995 | 328d |  |

| ID | WBS | Task | Duration | Start | Finish | Predecessors | Total slack | Free slack |
| --- | --- | --- | --- | --- | --- | --- | --- | --- |
| 997 | 1.5.6.7 | **3rd Floor** | 14d | 2011-11-24 | 2011-12-08 |  | 307d |  |
| 998 | 1.5.6.7.1 | Ducting/ Cable Work | 7d | 2011-11-24 | 2011-11-30 | 553 | 307d | 0d |
| 999 | 1.5.6.7.2 | Installation A/C | 7d | 2011-12-01 | 2011-12-08 | 998 | 307d | 20d |
| 1000 | 1.5.6.8 | **4th Floor** | 14d | 2012-01-06 | 2012-01-19 |  | 274d |  |
| 1001 | 1.5.6.8.1 | Ducting/ Cable Work | 7d | 2012-01-06 | 2012-01-12 | 583 | 274d | 0d |
| 1002 | 1.5.6.8.2 | Installation A/C | 7d | 2012-01-13 | 2012-01-19 | 1001 | 282d |  |
| 1003 | 1.5.6.9 | **5th Floor** | 14d | 2012-01-26 | 2012-02-09 |  | 254d |  |
| 1004 | 1.5.6.9.1 | Ducting/ Cable Work | 7d | 2012-01-26 | 2012-02-01 | 598 | 254d | 0d |
| 1005 | 1.5.6.9.2 | Installation A/C | 7d | 2012-02-02 | 2012-02-09 | 1004 | 262d |  |
| 1006 | 1.5.6.10 | **6th Floor** | 14d | 2012-02-16 | 2012-03-01 |  | 234d |  |
| 1007 | 1.5.6.10.1 | Ducting/ Cable Work | 7d | 2012-02-16 | 2012-02-23 | 613 | 234d | 0d |
| 1008 | 1.5.6.10.2 | Installation A/C | 7d | 2012-02-24 | 2012-03-01 | 1007 | 242d |  |
| 1009 | 1.5.6.11 | **7th Floor** | 14d | 2012-03-08 | 2012-03-22 |  | 214d |  |
| 1010 | 1.5.6.11.1 | Ducting/ Cable Work | 7d | 2012-03-08 | 2012-03-14 | 628 | 214d | 0d |
| 1011 | 1.5.6.11.2 | Installation A/C | 7d | 2012-03-15 | 2012-03-22 | 1010 | 222d |  |
| 1012 | 1.5.6.12 | **8th Floor** | 14d | 2012-03-29 | 2012-04-11 |  | 194d |  |
| 1013 | 1.5.6.12.1 | Ducting/ Cable Work | 7d | 2012-03-29 | 2012-04-04 | 643 | 194d | 0d |
| 1014 | 1.5.6.12.2 | Installation A/C | 7d | 2012-04-05 | 2012-04-11 | 1013 | 202d |  |
| 1015 | 1.5.6.13 | **9th Floor** | 14d | 2012-04-19 | 2012-05-03 |  | 174d |  |
| 1016 | 1.5.6.13.1 | Ducting/ Cable Work | 7d | 2012-04-19 | 2012-04-25 | 658 | 174d | 0d |
| 1017 | 1.5.6.13.2 | Installation A/C | 7d | 2012-04-26 | 2012-05-03 | 1016 | 182d |  |
| 1018 | 1.5.6.14 | **10th Floor** | 14d | 2012-05-10 | 2012-05-24 |  | 154d |  |
| 1019 | 1.5.6.14.1 | Ducting/ Cable Work | 7d | 2012-05-10 | 2012-05-16 | 673 | 154d | 0d |
| 1020 | 1.5.6.14.2 | Installation A/C | 7d | 2012-05-18 | 2012-05-24 | 1019 | 162d |  |

| ID | WBS | Task | Duration | Start | Finish | Predecessors | Total slack | Free slack |
| --- | --- | --- | --- | --- | --- | --- | --- | --- |
| 1021 | 1.5.6.15 | **11th Floor** | 14d | 2012-05-31 | 2012-06-13 |  | 134d |  |
| 1022 | 1.5.6.15.1 | Ducting/ Cable Work | 7d | 2012-05-31 | 2012-06-06 | 688 | 134d | 0d |
| 1023 | 1.5.6.15.2 | Installation A/C | 7d | 2012-06-07 | 2012-06-13 | 1022 | 142d |  |
| 1024 | 1.5.6.16 | **12th Floor** | 14d | 2012-06-20 | 2012-07-03 |  | 122d |  |
| 1025 | 1.5.6.16.1 | Ducting/ Cable Work | 7d | 2012-06-20 | 2012-06-26 | 703 | 122d | 0d |
| 1026 | 1.5.6.16.2 | Installation A/C | 7d | 2012-06-27 | 2012-07-03 | 1025 | 122d |  |
| 1027 | 1.5.6.17 | **13th Floor** | 14d | 2012-07-11 | 2012-07-24 |  | 102d |  |
| 1028 | 1.5.6.17.1 | Ducting/ Cable Work | 7d | 2012-07-11 | 2012-07-17 | 718 | 102d | 0d |
| 1029 | 1.5.6.17.2 | Installation A/C | 7d | 2012-07-18 | 2012-07-24 | 1028 | 102d |  |
| 1030 | 1.5.6.18 | **Top Floor** | 14d | 2012-07-26 | 2012-08-08 |  | 87d |  |
| 1031 | 1.5.6.18.1 | Ducting/ Cable Work | 7d | 2012-07-26 | 2012-08-01 | 733 | 87d | 0d |
| 1032 | 1.5.6.18.2 | Installation A/C | 7d | 2012-08-02 | 2012-08-08 | 1031 | 87d |  |
| 1033 | 1.5.7 | **BMS,CCTV,PABX,Intercom** | 90d | 2012-08-06 | 2012-11-17 |  | 0d |  |
| 1034 | 1.5.7.1 | CCTV | 90d | 2012-08-06 | 2012-11-17 | 764FF | 0d |  |
| 1035 | 1.5.7.2 | Access Control | 90d | 2012-08-06 | 2012-11-17 | 1034FF | 0d |  |
| 1036 | 1.5.7.3 | PABX | 90d | 2012-08-06 | 2012-11-17 | 1034FF | 0d |  |
| 1037 | 1.5.7.4 | Internet Net Work | 90d | 2012-08-06 | 2012-11-17 | 1034FF | 0d |  |
| 1038 | 1.5.7.5 | Central wify System | 90d | 2012-08-06 | 2012-11-17 | 1034FF | 0d |  |
| 1039 | 1.5.7.6 | Intercom | 90d | 2012-08-06 | 2012-11-17 | 1034FF | 0d |  |
| 1040 | 1.5.7.7 | BMS | 90d | 2012-08-06 | 2012-11-17 | 1034FF | 0d |  |
| 1041 | 1.5.7.8 | Parking Managenet System | 90d | 2012-08-06 | 2012-11-17 | 1034FF | 0d |  |
| 1042 | 1.5.8 | **Uitility Connection** | 162d | 2012-05-05 | 2012-10-23 |  | 19d |  |
| 1043 | 1.5.8.1 | **Power** | 121d | 2012-06-16 | 2012-10-23 |  | 19d |  |
| 1044 | 1.5.8.1.1 | Apply | 30d | 2012-06-16 | 2012-07-17 | 1045SF | 110d |  |
| 1045 | 1.5.8.1.2 | Process | 90d | 2012-07-17 | 2012-10-23 | 1046SF | 20d | 0d |
| 1046 | 1.5.8.1.3 | Connection | 1d | 2012-10-23 | 2012-10-23 | 897 | 19d | 0d |

| ID | WBS | Task | Duration | Start | Finish | Predecessors | Total slack | Free slack |
| --- | --- | --- | --- | --- | --- | --- | --- | --- |
| 1047 | 1.5.8.2 | **Water** | 121d | 2012-05-05 | 2012-09-11 |  | 60d |  |
| 1048 | 1.5.8.2.1 | Apply | 30d | 2012-05-05 | 2012-06-05 | 1049SF | 151d |  |
| 1049 | 1.5.8.2.2 | Process | 90d | 2012-06-05 | 2012-09-11 | 1050SF | 61d | 0d |
| 1050 | 1.5.8.2.3 | Connection | 1d | 2012-09-11 | 2012-09-11 | 826 | 60d | 0d |
| 1051 | 1.6 | **Miscellaneous Works** | 120d | 2012-07-06 | 2012-11-17 |  | 0d |  |
| 1052 | 1.6.1 | Water Recycle | 120d | 2012-07-06 | 2012-11-17 | 764FF | 0d |  |
| 1053 | 1.6.2 | Solar System | 120d | 2012-07-06 | 2012-11-17 | 1052FF | 0d |  |
| 1054 | 1.6.3 | Wind Power | 120d | 2012-07-06 | 2012-11-17 | 1052FF | 0d |  |
| 1055 | 1.6.4 | Rain Water Harvesting System | 120d | 2012-07-06 | 2012-11-17 | 1052FF | 0d |  |
| 1056 | 1.6.5 | **Water Treatment Plant** | 90d | 2012-08-06 | 2012-11-17 |  | 0d |  |
| 1057 | 1.6.5.1 | Grey Water Treatment | 90d | 2012-08-06 | 2012-11-17 | 764FF | 0d |  |
| 1058 | 1.6.5.2 | Rain Water Treatment | 90d | 2012-08-06 | 2012-11-17 | 1057FF | 0d |  |
| 1059 | 1.6.5.3 | Drinking Water Treatment | 90d | 2012-08-06 | 2012-11-17 | 1058FF | 0d |  |
| 1060 | 1.7 | Handover | 1d | 2012-11-18 | 2012-11-18 | 2, 475, 745, 762, 765, 1051 | 0d |  |
